# GNSO_Council_Program_Management_Tool_20201217

Schedule from MS Project, 2020-07-01 to 2026-06-30, A marks actual dates.

## Calendars

- Standard: Mon-Fri 08:00-12:00, 13:00-17:00; Sat-Sun off. Exceptions (off unless hours are given): 2021-03-20 08:00-12:00, 13:00-17:00, 2021-10-23 08:00-12:00, 13:00-17:00, 2023-04-01 08:00-12:00, 13:00-17:00, 2023-07-01 08:00-12:00, 13:00-17:00, 2024-12-01 08:00-12:00, 13:00-17:00.

## Resources

| Resource |
| --- |
| Council |
| Working Group |
| IRT |
| Board |
| Policy Staff |
| Council Leads |
| GDS Staff |
| SSC |
| Legal Staff |
| Finance Staff |
| Contracted Parties |
| EC Rep |
| EC Admin |

## Schedule

| ID | WBS | Task | Duration | Start | Finish | Predecessors | Complete | Remaining | Total slack | Free slack | Constraint | Resources | Work | Actual work |
| --- | --- | --- | --- | --- | --- | --- | --- | --- | --- | --- | --- | --- | --- | --- |
| 1 | 1 | **GNSO Program Management Planning** | 1570d | 2020-07-01 A | 2026-06-30 |  | 12% | 1375.41d | 0d |  |  |  | 366880h | 38663.6h |
| 2 | 1.1 | **RDDS - Program Track** | 823d | 2020-07-01 A | 2023-08-21 |  | 19% | 667.6d | 747d |  |  |  | 99584h | 14947.6h |
| 3 | 1.1.1 | **EPDP: Temporary Specification on gTLD Registration Data - Phase 2** | 733d | 2020-07-01 A | 2023-04-18 |  | 9% | 670d | 837d |  |  |  | 14688h | 1008h |
| 4 | 1.1.1.1 | Engage EPDP: Temporary Specification on gTLD Registration Data - Phase 2 | 23d | 2020-07-01 A | 2020-07-31 A |  | 100% |  |  |  |  | Policy Staff; Working Group | 368h | 368h |
| 5 | 1.1.1.2 | Council to deliberate and adopt working group consensus recommendations | 40d | 2020-08-03 A | 2020-09-25 A | 4 | 100% |  |  |  |  | Council; Policy Staff | 640h | 640h |
| 6 | 1.1.1.3 | Board to deliberate and adopt consensus recommendations | 150d | 2020-09-28 | 2021-04-22 | 5 |  |  | 837d | 0d |  | Board | 1200h |  |
| 7 | 1.1.1.4 | Engage IRT: Temporary Specification on gTLD Registration Data - Phase 2 | 520d | 2021-04-23 | 2023-04-18 | 6 |  |  | 837d |  |  | GDS Staff; IRT; Policy Staff | 12480h |  |
| 8 | 1.1.2 | **Remaining EPDP-P2 Topics (Legal vs. Natural, Unique Contacts, + Accuracy )** | 760d | 2020-09-28 A | 2023-08-21 |  | 5% | 721.66d | 747d |  |  |  | 17968h | 961.6h |
| 9 | 1.1.2.1 | **Remaining EPDP-P2 Topics Track 1 (Legal vs. Natural + Feasability of Unique Contacts)** | 473d | 2020-09-28 A | 2022-07-18 |  | 13% | 410.8d | 1034d |  |  |  | 7488h | 961.6h |
| 10 | 1.1.2.1.1 | Reset EPDP-P2A and elect new Chair | 58d | 2020-09-28 A | 2020-12-16 A | 5 | 100% |  |  |  |  | Council; Policy Staff | 928h | 928h |
| 11 | 1.1.2.1.2 | Engage EPDP-P2A to address remaining topics | 140d | 2020-12-17 A | 2021-06-29 | 10 | 3% | 135.8d | 1034d | 0d |  | Working Group | 1120h | 33.6h |
| 12 | 1.1.2.1.3 | Council to deliberate and adopt working group consensus recommendations | 45d | 2021-06-30 | 2021-08-31 | 11 |  |  | 1034d | 0d |  | Council; Policy Staff | 720h |  |
| 13 | 1.1.2.1.4 | Board to deliberate and adopt consensus recommendations | 50d | 2021-09-01 | 2021-11-08 | 12 |  |  | 1034d | 0d |  | Board | 400h |  |
| 14 | 1.1.2.1.5 | Engage IRT | 180d | 2021-11-09 | 2022-07-18 | 13 |  |  | 1034d |  |  | GDS Staff; IRT; Policy Staff | 4320h |  |
| 15 | 1.1.2.2 | **Remaining EPDP-P2 Topics Track 2 (Accuracy)** | 760d | 2020-09-28 | 2023-08-21 |  |  |  | 747d |  |  |  | 10480h |  |
| 16 | 1.1.2.2.1 | Staff to produce Briefing Document on Accuracy | 130d | 2020-09-28 | 2021-03-25 | 5 |  |  | 747d | 0d |  | GDS Staff | 1040h |  |
| 17 | 1.1.2.2.2 | Council to form Accuracy Scoping Team | 60d | 2021-03-26 | 2021-06-17 | 16 |  |  | 747d | 0d |  | Council; Policy Staff | 960h |  |
| 18 | 1.1.2.2.3 | Deliberate scope and decide to request Issues Report | 30d | 2021-06-18 | 2021-07-29 | 16, 17 |  |  | 747d | 0d | start no earlier than 2020-07-01 | Council; Policy Staff | 480h |  |
| 19 | 1.1.2.2.4 | Issues Report | 60d | 2021-07-30 | 2021-10-21 | 18 |  |  | 747d | 0d |  | Policy Staff | 480h |  |
| 20 | 1.1.2.2.5 | Council to approve PDP launch | 20d | 2021-10-22 | 2021-11-17 | 19 |  |  | 747d | 0d |  | Council; Policy Staff | 320h |  |
| 21 | 1.1.2.2.6 | Council to approve scope and charter | 40d | 2021-11-18 | 2022-01-12 | 20 |  |  | 747d | 0d |  | Council; Policy Staff | 640h |  |
| 22 | 1.1.2.2.7 | Engage RDS Accuracy PDP | 150d | 2022-01-13 | 2022-08-10 | 21 |  |  | 747d | 0d |  | Working Group | 1200h |  |
| 23 | 1.1.2.2.8 | Council to deliberate and adopt working group consensus recommendations | 40d | 2022-08-11 | 2022-10-05 | 22 |  |  | 747d | 0d |  | Council; Policy Staff | 640h |  |
| 24 | 1.1.2.2.9 | Board to deliberate and adopt consensus recommendations | 50d | 2022-10-06 | 2022-12-14 | 23 |  |  | 747d | 0d |  | Board | 400h |  |
| 25 | 1.1.2.2.10 | Engage IRT | 180d | 2022-12-15 | 2023-08-21 | 24 |  |  | 747d |  |  | GDS Staff; IRT; Policy Staff | 4320h |  |

Notes:
- 9: Recommendation for consideration: / Based on the current status of work and considering the most efficient way to address the priority topics that are expected to remain, as the GNSO Council liaison to the EPDP, I would suggest the Council consider moving forward with option 3 in the following manner: / ·Reset the PDP to allow for further consideration and completion of the charter to address the following two topics: 1) legal vs natural persons and 2) Feasibility of unique contacts to have a uniform anonymized email address. A specific timeline (e.g. 3 months) after reconvening should be set for the EPDP Team to report back to determine the likelihood of consensus emerging on these topics. Note, if no consensus can be found for Consensus Policy recommendations, the EPDP Team could also consider guidance or best practices to Contracted Parties for these topics based on its consideration of these topics. Based on the feedback from the EPDP Team, the Council would decide whether further time would be granted to the EPDP Team to complete its work or whether termination of the EPDP would be in order.
- 15: Recommendation for consideration: / Based on the current status of work and considering the most efficient way to address the priority topics that are expected to remain, as the GNSO Council liaison to the EPDP, I would suggest the Council consider moving forward with option 3 in the following manner: / ·Convene a scoping team to further consider the topic of accuracy - the scoping team would be expected to identify what specific issues, if any, need to be addressed in relation to accuracy and identify the best path for addressing these issues. The findings of the scoping team would be presented to the GNSO Council for its consideration.

| ID | WBS | Task | Type | Duration | Start | Finish | Predecessors | Complete | Remaining | Total slack | Free slack | Constraint | Resources | Work | Actual work |
| --- | --- | --- | --- | --- | --- | --- | --- | --- | --- | --- | --- | --- | --- | --- | --- |
| 26 | 1.1.3 | **RDS2 Review Items** |  | 578d | 2020-07-23 A | 2022-10-06 |  | 94% | 36.12d | 976d |  |  |  | 512h | 480h |
| 27 | 1.1.3.1 | **RDS2 Review - Recommendation CC.1 (suspension of domain due to incorrect RDS)** |  | 578d | 2020-07-23 A | 2022-10-06 |  | 83% | 96.33d | 976d |  |  |  | 192h | 160h |
| 28 | 1.1.3.1.1 | Reply to Board on proposed action |  | 10d | 2020-07-23 A | 2020-08-05 A |  | 100% |  |  |  |  | Council; Policy Staff | 160h | 160h |
| 29 | 1.1.3.1.2 | Determine if CC.1 can be coupled with Remaining EPDP-P2 Topics (Accuracy) |  | 1d | 2021-10-22 | 2021-10-22 | 18, 28, 19 |  |  | 1226d |  |  | Council; Policy Staff | 16h |  |
| 30 | 1.1.3.1.3 | CC.1 Implemented |  | 1d | 2022-10-06 | 2022-10-06 | 23 |  |  | 976d |  |  | Council; Policy Staff | 16h |  |
| 31 | 1.1.3.2 | **RDS2 Review - Recommendation CC.4 (measure, audit, etc. of RDS Policies)** |  | 10d | 2020-07-23 A | 2020-08-05 A |  | 100% |  |  |  |  |  | 320h | 320h |
| 32 | 1.1.3.2.1 | Reply to Board on proposed action |  | 10d | 2020-07-23 A | 2020-08-05 A |  | 100% |  |  |  |  | Council; Policy Staff | 160h | 160h |
| 33 | 1.1.3.2.2 | Council will take no action as operating procedures already allow for this |  | 10d | 2020-07-23 A | 2020-08-05 A |  | 100% |  |  |  | start no earlier than 2020-07-23 | Council; Policy Staff | 160h | 160h |
| 34 | 1.1.4 | **IRT: Temporary Specification on gTLD Registration Data - Phase 1** |  | 546d | 2020-07-01 A | 2022-08-01 |  | 37% | 344.18d | 1024d |  |  |  | 39136h | 11538h |
| 35 | 1.1.4.1 | Engage IRT: Temporary Specification on gTLD Registration Data - Phase 1 |  | 545d | 2020-07-01 A | 2022-08-01 |  | 55% | 245.25d | 1024d |  |  | GDS Staff; IRT; Policy Staff | 13080h | 7194h |
| 36 | 1.1.4.2 | **EPDP-P1 Rec27 Wave 1 Other Policy Impacts** |  | 344d | 2020-07-01 A | 2021-10-22 |  | 31% | 236.34d | 1226d |  |  |  | 26056h | 4344h |
| 37 | 1.1.4.2.1 | **Add Grace Period (AGP) Limits Policy [LOW]** |  | 1d | 2020-07-01 A | 2020-07-01 A |  | 100% |  |  |  |  |  | 8h | 8h |
| 38 | 1.1.4.2.1.1 | No impacts as a result of Registration Data Services Policy implementation |  | 1d | 2020-07-01 A | 2020-07-01 A |  | 100% |  |  |  |  | GDS Staff | 8h | 8h |
| 39 | 1.1.4.2.2 | **Additional Whois Information Policy (AWIP) [LOW]** |  | 110d | 2020-09-04 A | 2021-02-04 |  | 41% | 65d | 1413d |  |  |  | 1600h | 360h |
| 40 | 1.1.4.2.2.1 | Produce redlines of consensus policy provisions (assumes step 2 accomplished here) | manual | 45d | 2020-09-04 A | 2020-11-05 A |  | 100% |  |  |  |  | GDS Staff | 360h | 360h |
| 41 | 1.1.4.2.2.2 | Review and confirm redlines for final changes |  | 30d | 2020-11-06 | 2020-12-17 | 40 |  |  | 1413d | 0d |  | GDS Staff; IRT; Policy Staff | 720h |  |
| 42 | 1.1.4.2.2.3 | Conduct public comment of changes |  | 30d | 2020-12-18 | 2021-01-28 | 41 |  |  | 1413d | 0d |  | GDS Staff; IRT | 480h |  |
| 43 | 1.1.4.2.2.4 | Post updated consensus policy |  | 5d | 2021-01-29 | 2021-02-04 | 42 |  |  | 1413d |  |  | GDS Staff | 40h |  |
| 44 | 1.1.4.2.3 | **Expired Domain Deletion Policy (EDDP) [MEDIUM]** |  | 120d | 2020-09-04 A | 2021-02-18 |  | 38% | 75d | 1403d |  |  |  | 1840h | 360h |
| 45 | 1.1.4.2.3.1 | Produce redlines of consensus policy provisions | manual | 45d | 2020-09-04 A | 2020-11-05 A |  | 100% |  |  |  |  | GDS Staff | 360h | 360h |
| 46 | 1.1.4.2.3.2 | Review and confirm redlines for final changes |  | 40d | 2020-11-06 | 2020-12-31 | 45 |  |  | 1403d | 0d |  | GDS Staff; IRT; Policy Staff | 960h |  |
| 47 | 1.1.4.2.3.3 | Conduct public comment of changes |  | 30d | 2021-01-01 | 2021-02-11 | 46 |  |  | 1403d | 0d |  | GDS Staff; IRT | 480h |  |
| 48 | 1.1.4.2.3.4 | Post updated consensus policy |  | 5d | 2021-02-12 | 2021-02-18 | 47 |  |  | 1403d |  |  | GDS Staff | 40h |  |
| 49 | 1.1.4.2.4 | **Expired Registration Recovery Policy (ERRP) [LOW]** |  | 120d | 2020-09-04 A | 2021-02-18 |  | 38% | 75d | 1403d |  |  |  | 1840h | 360h |
| 50 | 1.1.4.2.4.1 | Produce redlines of consensus policy provisions | manual | 45d | 2020-09-04 A | 2020-11-05 A |  | 100% |  |  |  |  | GDS Staff | 360h | 360h |
| 51 | 1.1.4.2.4.2 | Review and confirm redlines for final changes |  | 40d | 2020-11-06 | 2020-12-31 | 50 |  |  | 1403d | 0d |  | GDS Staff; IRT; Policy Staff | 960h |  |
| 52 | 1.1.4.2.4.3 | Conduct public comment of changes |  | 30d | 2021-01-01 | 2021-02-11 | 51 |  |  | 1403d | 0d |  | GDS Staff; IRT | 480h |  |
| 53 | 1.1.4.2.4.4 | Post updated consensus policy |  | 5d | 2021-02-12 | 2021-02-18 | 52 |  |  | 1403d |  |  | GDS Staff | 40h |  |

Notes:
- 27: Recommendation CC.1: The ICANN Board should initiate action intended to ensure that gTLD domain names suspended due to RDS (WHOIS) contact data which the registrar knows to be incorrect, and that remains incorrect until the registration is due for deletion, should be treated as follows: (1) The RDS (WHOIS) record should include a notation that the domain name is suspended due to incorrect data; and (2) Domain names with this notation should not be unsuspended without correcting the data. / Board resolution: The Board approved this recommendation and directed this item to be included in the next round of contractual negotiations with the Contracted Parties, with a note that it cannot require or guarantee any negotiation outcomes. The Board also noted that this is an area that the GNSO Council might wish to take into a policy development process separate from any recourse to the policy development process that might be incorporated into the negotiation process, and passed through this recommendation to the GNSO Council for purposes of considering such initiation. / GNSO Council response: / This recommendations touches upon accuracy of registration data, which is one of the priority two topics for Phase 2 of the GNSOs Expedited Policy Development Process on Temporary Specification for gTLD Registration Data (EPDP). However, the Council is well aware that data accuracy, among some other priority two topics, is unlikely to be addressed by the EPDP Team and is considering its options and possible next steps. / If and when the Council decides to request an Issue Report on data accuracy, Recommendation CC.1 could be included for consideration, if this item has not bee addressed in the next round of contractual negotiations between ICANN org and the Contracted Parties (as directed by the Board).
- 31: Recommendation CC.4: The ICANN Board should recommend the GNSO adopt a risk-based approach to incorporating requirements for measurement, auditing, tracking, reporting and enforcement in all new RDS policies. / Board resolution: The Board passed the recommendation through to the GNSO Council, with reference to documentation of clarifications received from RDS-WHOIS2 Implementation Shepherds in the 29 January 2020 discussion with the RDS Board Caucus Group, i.e. this recommendation could be directed to the GNSO. / GNSO Council response: / Recommendation CC.4 touches upon two main areas: / 1. How to measure effectiveness of RDS policies; and / 2.Enforcement of RDS polices by ICANN Contractual Compliance. / With regard to #1, the Council is of the view that this has been, by and large, addressed by the non-PDP Data & Metrics for Policy Making Working Group (DMPM WG) and the GNSO2 Review. / One of the recommendations in the DMPM WGs Final Report was to include the following language in the GNSO Working Group Charter template, which has been duly implemented: / Deliverables: / …. / If the WG concludes with any recommendations, the WG must include a policy impact analysis and a set of metrics to measure the effectiveness of the policy change, including source(s) of baseline data for that purpose: / ·Identification of policy goals/ ·Identification of metrics used to measure whether policy goals are achieved / ·Identification of potential problems in attaining the data or developing the metrics / ·A suggested timeframe in which the measures should be performed / ·Define current state baselines of the policy and define initial benchmarks that define success or failure / ·Metrics may include but not limited to (Refer to the Hints & Tips Page): / ·ICANN Compliance data / ·Industry metric sources / ·Community input via public comment / ·Surveys or studies / In addition, Recommendation 16 of GNSO2 Review Final Report was that a policy impact assessment (PIA) be included as a standard part of any policy process. Subsequently, the following language is included in the GNSO Operating Procedures as part of the implementation of this recommendation: / 11. Publication of the Initial Report / After collection and review of information, the PDP Team and Staff are responsible for producing an Initial Report. The Initial Report should include the following elements: / … / ·A statement on the WG discussion concerning impact of the proposed recommendations, which could consider areas such as economic, competition, operations, privacy and other rights, scalability and feasibility. / With regard to #2, ICANN Compliance activities (including its audit program, approach, complaints handling processes, monitoring, reporting are well documented and published on ICANN website https://www.icann.org/resources/pages/compliance-2012-02-25-en. / Based on the above, the Council does not propose to take any further action in relation to Recommendation CC.4.
- 37: Add Grace Period (AGP) Limits Policy / This policy was developed to limit the behavior known as domain tasting through modifications to the Add Grace Period process. Under this policy, a registry operator does not refund fees to a registrar who exceeds a defined threshold percentage of names deleted during the Add Grace Period. 1. Consistency of terminology (WHOIS/RDS/Whois data/Registration data) / 2.ICANN org has not identified any substantive impact on the existing requirements of this policy / 3.In the policy section titled Effect on Registrars, the Exemption Requests section provides that a registry operator can require additional information from a registrar to process an exemption request. To the extent this involves personal data associated with a domain name, this requirement may be subject to separate arrangements between the registry and registrar regarding the processing of personal data 1. Request EPDP Phase 1 IRT or establish new IRT to address terminology updates / 2.None / 3.Out of scope for Council action
- 39: Additional Whois Information Policy (AWIP) / The purpose of this policy is to clarify the meaning of the EPP status codes in Whois data and require the consistent identification of registrars by their GURID in Whois. 1. An update to the name of the policy may be considered as title includes Whois, which may not remain necessary. Other terminology references to Whois output and Whois data throughout the text may also be considered for updates, for example, section 1(c), "For more information on Whois status codes, please visit https://icann.org/epp". / 2.There is an additional technical consideration to applying this policy in RDAP. The protocol does not currently support inclusion of a hyperlink in each status field; rather, a hyperlink can be included at the object level (e.g., domain object, contact object). This can be addressed by (a) adjusting the language of the policy to include the hyperlink reference to the status codes definition page in a single place rather than multiple places, or (b) developing an RDAP extension. Approach (a) is reflected in the current gTLD RDAP Profile; however, adherence to this profile is a recommendation but not a requirement for contracted parties. 1. Request EPDP Phase 1 IRT or establish new IRT to address terminology updates / 2.If a), request EPDP Phase 1 IRT or new IRT to address adding of hyperlink reference, if b) out of scope for Council action.
- 44: Expired Domain Deletion Policy (EDDP) / This policy covers various registrar practices for deletion of a domain name registration where a registrant has not renewed. 1. Consistency of terminology (WHOIS/RDS/Whois data/Registration data) / 2.EDDP section 3.7.5.7 references WHOIS contact information and the WHOIS entry. The context of this provision is a requirement that, if a registration expires during a UDRP proceeding, the complainant has the option to renew or restore the registration on the same commercial terms as the registrant. Where this occurs, the EDDP requires that the registrar (a) place the registration in Registrar HOLD and Registrar LOCK2 statuses, (b) remove the registrant contact information from the WHOIS, and (c) include a message in the WHOIS output that the registration is subject to a dispute resolution proceeding. / Under the new Registration Data Policy, as there may be no registrant contact information that is publicly displayed, the registrar may not need to take any action to remove the contact information from publicly available data. However, in the event that there is any such registrant contact information being displayed (for example, where processing is not subject to GDPR or as a result of the registrants consent), the current requirement would apply and that data would be removed. In addition, for non-public data, the registrar should also update its (non-public) registration data to remove the registrant information and indicate the pendency of a dispute resolution proceeding. This section may benefit from some clarification to indicate how these requirements apply under the Registration Data Policy. / The requirements to update the status of the registration and to indicate in the publicly available data that the name is subject to a dispute are unaffected. However, additional guidance may be required on what and where to display this message in RDDS output, for example, if the Registration Data Policy requires a Redacted for Privacy notation and the EDDP requires a notation that the name is subject to a dispute proceeding. Note that RDAP is able to support multiple notations in an output. / ICANN org notes that this provision is occasionally invoked to keep a registration active during a dispute resolution proceeding. If changes are considered to this policy as a result of GNSO policy work, it may be beneficial to apply this option to URS cases also. 1. Request EPDP Phase 1 IRT or establish new IRT to address terminology updates / 2.Initiate an overall review of the policy by requesting GDD to prepare a Policy Status Report as a first step (consider whether review of this policy could be combined with a review of the Expired Registration Recovery Policy?)
- 49: Expired Registration Recovery Policy (ERRP) / The ERRP is intended to help align registrant expectations with registrar practices by establishing certain minimum communications requirements, making renewal and redemption of registrations uniformly available in prescribed circumstances, and through the creation and promotion of registrant educational materials. 1. Consistency of terminology (WHOIS/RDS/Whois data/Registration data) / 2.ERRP section 4.2.1 references the Administrative Contact. The context of this provision is a requirement that registrars describe on their websites the contact methods they use to deliver the pre- and post-expiration notifications described in the policy. Telephone call to administrative contact is one of the examples; however, this example can be eliminated without impact to the policy requirements. / 3.The ERRP section titled Time for Coming into Compliance provides milestones by which registrars must send notices after the effective date of the ERRP. If changes are considered to this policy as a result of GNSO policy work, this section may be eliminated as obsolete. Note, the ERRP is already slated for review on the GNSO Project list (no date confirmed as of now) 1. Request EPDP Phase 1 IRT or establish new IRT to address terminology updates / 2.Request EPDP Phase 1 IRT or establish new IRT to address / update reference to administrative contact / 3.Incorporate this in the review of the ERRP that has already been anticipated and request GDD to prepare a Policy Status Report as a first step (consider whether review of this policy could be combined with a review of the Expired Domain Deletion Policy?)

| ID | WBS | Task | Type | Duration | Start | Finish | Predecessors | Complete | Remaining | Total slack | Free slack | Resources | Work | Actual work |
| --- | --- | --- | --- | --- | --- | --- | --- | --- | --- | --- | --- | --- | --- | --- |
| 54 | 1.1.4.2.5 | **Protection of IGO / INGO Identifiers in All gTLDs Policy [LOW]** |  | 1d | 2020-07-01 A | 2020-07-01 A |  | 100% |  |  |  |  | 8h | 8h |
| 55 | 1.1.4.2.5.1 | No impacts as a result of Registration Data Services Policy implementation | manual | 1d | 2020-07-01 A | 2020-07-01 A |  | 100% |  |  |  | GDS Staff | 8h | 8h |
| 56 | 1.1.4.2.6 | **Registry Registration Data Directory Services Consistent Labeling and Display Policy (CL&D) [HIGH]** |  | 90d | 2020-08-03 | 2020-12-04 |  |  |  | 0d |  |  | 2080h |  |
| 57 | 1.1.4.2.6.1 | Council to determine next steps based on EPDP-P1-IRT + Rec27 findings | manual | 60d | 2020-09-04 | 2020-11-26 |  |  |  |  |  | Council; Policy Staff | 960h |  |
| 58 | 1.1.4.2.6.2 | Produce redlines of consensus policy provisions | manual | 45d | 2020-08-03 | 2020-10-02 |  |  |  |  |  | GDS Staff | 360h |  |
| 59 | 1.1.4.2.6.3 | Review and confirm redlines for final changes |  | 10d | 2020-10-05 | 2020-10-16 | 58 |  |  | 1457d | 0d | GDS Staff; IRT; Policy Staff | 240h |  |
| 60 | 1.1.4.2.6.4 | Conduct public comment of changes |  | 30d | 2020-10-19 | 2020-11-27 | 59 |  |  | 1457d | 0d | GDS Staff; IRT | 480h |  |
| 61 | 1.1.4.2.6.5 | Post updated consensus policy |  | 5d | 2020-11-30 | 2020-12-04 | 60 |  |  | 1457d |  | GDS Staff | 40h |  |
| 62 | 1.1.4.2.7 | **Registry Services Evaluation Policy [LOW]** |  | 1d | 2020-07-01 A | 2020-07-01 A |  | 100% |  |  |  |  | 8h | 8h |
| 63 | 1.1.4.2.7.1 | No impacts as a result of Registration Data Services Policy implementation |  | 1d | 2020-07-01 A | 2020-07-01 A |  | 100% |  |  |  | GDS Staff | 8h | 8h |
| 64 | 1.1.4.2.8 | **Restored Names Accuracy Policy (RNAP) [LOW]** |  | 297d | 2020-09-04 A | 2021-10-22 |  | 37% | 186.55d | 1226d |  |  | 1856h | 360h |
| 65 | 1.1.4.2.8.1 | **Track 1 - Item 1** |  | 120d | 2020-09-04 A | 2021-02-18 |  | 38% | 75d | 1403d |  |  | 1840h | 360h |
| 66 | 1.1.4.2.8.1.1 | Produce redlines of consensus policy provisions | manual | 45d | 2020-09-04 A | 2020-11-05 A |  | 100% |  |  |  | GDS Staff | 360h | 360h |
| 67 | 1.1.4.2.8.1.2 | Review and confirm redlines for final changes |  | 40d | 2020-11-06 | 2020-12-31 | 66 |  |  | 1403d | 0d | GDS Staff; IRT; Policy Staff | 960h |  |
| 68 | 1.1.4.2.8.1.3 | Conduct public comment of changes |  | 30d | 2021-01-01 | 2021-02-11 | 67 |  |  | 1403d | 0d | GDS Staff; IRT | 480h |  |
| 69 | 1.1.4.2.8.1.4 | Post updated consensus policy |  | 5d | 2021-02-12 | 2021-02-18 | 68 |  |  | 1403d |  | GDS Staff | 40h |  |
| 70 | 1.1.4.2.8.2 | **Track 2 - Item 2** |  | 1d | 2021-10-22 | 2021-10-22 |  |  |  | 0d |  |  | 16h |  |
| 71 | 1.1.4.2.8.2.1 | Migrated to Remaining EPDP-P2 Topics Track 2 (Accuracy) | manual | 1d | 2021-10-22 | 2021-10-22 | 19 |  |  |  |  | Council; Policy Staff | 16h |  |
| 72 | 1.1.4.2.9 | **Revised ICANN Procedure for Handling Whois Conflicts with Privacy Law [LOW]** |  | 120d | 2020-09-04 A | 2021-02-18 |  | 38% | 75d | 1403d |  |  | 1840h | 360h |
| 73 | 1.1.4.2.9.1 | **Track 1 - Items 1 to 3** |  | 120d | 2020-09-04 A | 2021-02-18 |  | 38% | 75d | 1403d |  |  | 1840h | 360h |
| 74 | 1.1.4.2.9.1.1 | Produce redlines of consensus policy provisions | manual | 45d | 2020-09-04 A | 2020-11-05 A |  | 100% |  |  |  | GDS Staff | 360h | 360h |
| 75 | 1.1.4.2.9.1.2 | Review and confirm redlines for final changes |  | 40d | 2020-11-06 | 2020-12-31 | 74 |  |  | 1403d | 0d | GDS Staff; IRT; Policy Staff | 960h |  |
| 76 | 1.1.4.2.9.1.3 | Conduct public comment of changes |  | 30d | 2021-01-01 | 2021-02-11 | 75 |  |  | 1403d | 0d | GDS Staff; IRT | 480h |  |
| 77 | 1.1.4.2.9.1.4 | Post updated consensus policy |  | 5d | 2021-02-12 | 2021-02-18 | 76 |  |  | 1403d |  | GDS Staff | 40h |  |

Notes:
- 54: Protection of IGO / INGO Identifiers in All gTLDs Policy / This policy relates to protection at the top and second level for specific Red Cross, IOC and IGO names (with an Exception Procedure to be designed for the relevant protected organizations), protection at the top level for specific INGO names and a 90-day Claims Notification process at the second level for certain other INGO names. The policy provides requirements for contracted parties with respect to second-level DNS labels and requirements relating to the delegation of protected gTLD strings. 1. Consistency of terminology (WHOIS/RDS/Whois data/Registration data) 1. Request EPDP Phase 1 IRT or establish new IRT to address terminology updates
- 56: * .; ; .; ; Registry Registration Data Directory Services Consistent Labeling and Display Policy (CL & D) / The goal of the RDDS Consistent Labeling and Display Policy is to align the way registries and registrars label and display registration data outputs. This policy specifies the format for responses to domain name queries. 1.Consistency of terminology (WHOIS/RDS/Whois data/Registration data) / 2.The format specified by CL&D for published registration data will not be possible under the requirements of the new Registration Data Policy, based on the following: / a.Section 7 requires a registry operator to use a Registry Admin ID key in responses to a domain name object query. Under the Registration Data Policy, Administrative Contact data is no longer collected or transferred from a registrar to a registry operator. / b.Section 10 notes that a registry operator that is permitted to provide redacted RDDS output in its registry agreement may treat certain fields as optional. In some cases, redaction of these fields is specified in the Registration Data Policy, and in others, such as the Administrative Contact fields, these fields will no longer be required to be collected or transferred from the registrar to the registry operator. This section may be removed or updated to align with the Registration Data Policy language.~/ c.Section 11 specifies that the fields for Registry Admin/Tech/Billing/Registrant ID refer to the Repository Object Identifier (ROID) for the contact object as specified in RFC 5733. The Admin ID may be eliminated as administrative contact information will no longer be collected or transferred from the registrar to the registry operator. It is also noted that not all gTLD registry operators currently use a Registrant ID field, and implementing this may involve a transition period. Under the Registration Data Policy, the Registry Registrant ID field is required to be transferred by the registry operator to a data escrow agent (per EPDP Recommendation 8), and may be required to be published or to be redacted with the opportunity for a registrant to consent to its publication (per EPDP Recommendation 10).~/ d.In regard to ROID, per RFC 5733, the ROID is a <contact:id> element that contains the desired server-unique identifier for the contact to be created. EPDP Recommendation 5 does not specify the Registry Registrant ID as a data element to be collected or generated. As the Extensible Provisioning Protocol (EPP) requires this information to create a contact, current implementation language for the EPDP Phase 1 recommendations includes the notation that nothing in this policy changes the collection of the following data elements required by EPP: <contact:id> (Registry Registrant ID, Registry Tech ID), <contact:authInfo>, <contact:city>, <contact:cc> For the registrar~to display this, it must be transferred from the registry. / 3.If changes are considered to this policy as a result of GNSO policy work, it may be beneficial to define to what extent the same type of consistency in labeling and display reflected in this policy remains the goal or should be adjusted. It should be noted that, according to the Registration Data Policy, both registry and registrar publication of data for individual registrations may differ on the basis of conditional policy requirements, (e.g., fields specified in the policy as MUST publish IF collected), differentiation geographically or on the basis of a legal or natural persons classification, and consent of the data subject for publication of certain data fields. The format of the display output for published registration data is impacted by the Registration Data Policy; however, some types of consistency are still possible. If the policy goal of the desired type and nature of consistency in labeling and display can be reviewed and defined, next steps can follow by determining the best means by which this can be accomplished, e.g., updates to the CL&D policy language to conform to the EPDP Teams Phase 1 recommendations, including a specified format in the new Registration Data Policy, requirements in an updated RDAP Profile, or other means. Note, an IRT is still in place but on hold as the implementation of this policy was halted pending the roll-out of RDAP. 1. Request Translation and Transliteration of Contact Information (T & T) IRT to address terminology updates / 2.Request T&T to review these issues and identify which ones can be addressed through implementation and which ones may require policy changes through a PDP / 3.Consider following outcome of 2 if a PDP is to be initiated, these issues can be considered as part of the PDP
- 62: Registry Services Evaluation Policy / This policy provides for ICANN org to evaluate a proposed Registry Service for potential significant security, stability, and competition issues. gTLD Registry Agreements identify the RSEP process as the mechanism for a gTLD registry operator to submit a request to ICANN organization to add a proposed service, modify an existing service, or remove an existing service. 1. Consistency of terminology (WHOIS/RDS/Whois data/Registration data) / 1. Request EPDP Phase 1 IRT or establish new IRT to address terminology updates
- 64: Restored Names Accuracy Policy (RNAP) / This policy provides that when a domain name registration is deleted on the basis of submission of false contact data or non-response to registrar inquiries, if a registrar restores the name from the Redemption Grace Period, the name must be placed on Registrar Hold status5 until the registrant has provided updated and accurate contact data. The policy recommendations for this policy noted that: the purpose of this policy is to make~sure that the redemption process cannot be used as a tool to bypass registrar's contact correction process.~ 1. Consistency of terminology (WHOIS/RDS/Whois data/Registration data) / 2.The policy requires names restored during the Redemption Grace Period after having been deleted for submission of false contact data or non-response to registrar inquiries to be placed in Registrar Hold status. If changes are considered to this policy as a result of GNSO policy work, this reference may be updated to the EPP status Client Hold.~/ 1. Request EPDP Phase 1 IRT or establish new IRT to address terminology updates / 2.None at this stage, but make note of this item should a future PDP look at this policy.
- 72: * .; ; .; ; WHOIS Procedure Implementation Advisory Group (WPIAG) / The ICANN Procedure For Handling WHOIS Conflicts with Privacy Law Implementation Advisory Group (WHOIS Procedure IAG) is tasked to provide the GNSO Council with recommendations on how to address the comments and input that has been received in response to the public comment forum on the Revised ICANN Procedure for Handling WHOIS Conflicts with Privacy Law: Process and Next Steps. / ·Following discussion at the 13 March 2019 Council meeting, the Council agreed to defer further discussion of the WPIAG for 12 months but reserves the right to revisit the deferral period at any time. This topic was initiated at the Council 22 Feb 2018. / Current Activities:/ ·This issue is being considered by the GNSO Council as identified within the EPDP-P1 , Rec#27 Impact to Existing Policies Report (Wave 1). / Completed in prior period(s):/ ·The GNSO Council adopted the charter for the ICANN Procedure For Handling WHOIS Conflicts with Privacy Law Implementation Advisory Group (WHOIS Procedure IAG) during its meeting on 22 February 2018.~/ ·Per the Councils recent discussions, noting the current workload and activities that may impact the IAGs work, staff is refraining from circulating the call for volunteers to the GNSO Stakeholder Groups until the EPDP Team completes certain milestones (e.g., delivery of its Final Report). / Revised ICANN Procedure for Handling Whois Conflicts with Privacy Law / This policy allows ICANN and contracted parties (both ICANN-accredited registrars and gTLD registries) to demonstrate when they are prevented from complying with contractual obligations to collect, display, or distribute registration data because of a conflict with other legal obligations, namely, local or national laws. 1.Consistency of terminology (WHOIS/RDS/Whois data/Registration data) / 2.If changes are considered to this policy as a result of GNSO policy work, for consistency with other policies, it may be useful to consider the following updates: / a.adding a definitions section with relevant terms referenced in the gTLD Registration Data Policy.~ / b.to the extent the section titled Introduction and Background is retained, updating the text to describe the background, history, and rationale for changes to the procedure.~ / c.the name of the procedure and references to Whois throughout, e.g., Whois Proceeding.~ / 3.Feedback from some stakeholders in June 2019 during an ICANN65 session questioned whether this procedure was the right instrument to solve a problem, or suggested that the lack of use of the procedure was an indication it had not met its policy objectives. The GNSO may wish to consider this feedback in determining next steps. Note, that the Council is expected to consider at the end of March whether/when to launch the ICANN Procedure For Handling WHOIS Conflicts with Privacy Law Implementation Advisory Group (WHOIS Procedure IAG). This group will be tasked to provide the GNSO Council with recommendations on how to address the comments and input that has been received in response to the public comment forum on the Revised ICANN Procedure for Handling WHOIS Conflicts with Privacy Law: Process and Next Steps. / 1. Request the WHOIS Procedure IAG to consider consistency of terminology / 2.Request the WHOIS Procedure IAG to consider these items (should policy changes be required, the IAG is expected to advice the GNSO Council accordingly) / 3.Request the WHOIS Procedure IAG To consider this input and advice the Council accordingly.

| ID | WBS | Task | Type | Duration | Start | Finish | Predecessors | Complete | Remaining | Total slack | Free slack | Constraint | Resources | Work | Actual work |
| --- | --- | --- | --- | --- | --- | --- | --- | --- | --- | --- | --- | --- | --- | --- | --- |
| 78 | 1.1.4.2.10 | **Thick Whois Transition Policy for .COM, .NET, .JOBS [HIGH]** |  | 90d | 2020-09-04 | 2021-01-07 |  |  |  | 0d |  |  |  | 2080h |  |
| 79 | 1.1.4.2.10.1 | Council to determine next steps based on EPDP-P1-IRT + Rec27 findings | manual | 60d | 2020-09-04 | 2020-11-26 |  |  |  |  |  | start no earlier than 2020-09-04 | Council; Policy Staff | 960h |  |
| 80 | 1.1.4.2.10.2 | Produce redlines of consensus policy provisions | manual | 45d | 2020-09-04 | 2020-11-05 |  |  |  |  |  |  | GDS Staff | 360h |  |
| 81 | 1.1.4.2.10.3 | Review and confirm redlines for final changes |  | 10d | 2020-11-06 | 2020-11-19 | 80 |  |  | 1433d | 0d |  | GDS Staff; IRT; Policy Staff | 240h |  |
| 82 | 1.1.4.2.10.4 | Conduct public comment of changes |  | 30d | 2020-11-20 | 2020-12-31 | 81 |  |  | 1433d | 0d |  | GDS Staff; IRT | 480h |  |
| 83 | 1.1.4.2.10.5 | Post updated consensus policy |  | 5d | 2021-01-01 | 2021-01-07 | 82 |  |  | 1433d |  |  | GDS Staff | 40h |  |
| 84 | 1.1.4.2.11 | **Transfer Policy [HIGH]** |  | 120d | 2020-09-04 A | 2021-02-18 |  | 38% | 75d | 1403d |  |  |  | 1840h | 360h |
| 85 | 1.1.4.2.11.1 | Produce redlines of consensus policy provisions (Items 1,2,3 & 6) | manual | 45d | 2020-09-04 A | 2020-11-05 A |  | 100% |  |  |  |  | GDS Staff | 360h | 360h |
| 86 | 1.1.4.2.11.2 | Review and confirm redlines for final changes |  | 40d | 2020-11-06 | 2020-12-31 | 85 |  |  | 1403d | 0d |  | GDS Staff; IRT; Policy Staff | 960h |  |
| 87 | 1.1.4.2.11.3 | Conduct public comment of changes |  | 30d | 2021-01-01 | 2021-02-11 | 86 |  |  | 1403d | 0d |  | GDS Staff; IRT | 480h |  |
| 88 | 1.1.4.2.11.4 | Post updated consensus policy |  | 5d | 2021-02-12 | 2021-02-18 | 87 |  |  | 1403d |  |  | GDS Staff | 40h |  |
| 89 | 1.1.4.2.12 | **Transfer Dispute Resolution Policy (TDRP) [HIGH]** |  | 120d | 2020-09-04 A | 2021-02-18 |  | 38% | 75d | 1403d |  |  |  | 1840h | 360h |
| 90 | 1.1.4.2.12.1 | Produce redlines of consensus policy provisions | manual | 45d | 2020-09-04 A | 2020-11-05 A |  | 100% |  |  |  |  | GDS Staff | 360h | 360h |
| 91 | 1.1.4.2.12.2 | Review and confirm redlines for final changes |  | 40d | 2020-11-06 | 2020-12-31 | 90 |  |  | 1403d | 0d |  | GDS Staff; IRT; Policy Staff | 960h |  |
| 92 | 1.1.4.2.12.3 | Conduct public comment of changes |  | 30d | 2021-01-01 | 2021-02-11 | 91 |  |  | 1403d | 0d |  | GDS Staff; IRT | 480h |  |
| 93 | 1.1.4.2.12.4 | Post updated consensus policy |  | 5d | 2021-02-12 | 2021-02-18 | 92 |  |  | 1403d |  |  | GDS Staff | 40h |  |
| 94 | 1.1.4.2.13 | **Rules for Uniform Domain Name Dispute Resolution Policy (UDRP Rules) [HIGH]** |  | 120d | 2020-08-03 A | 2021-01-15 |  | 38% | 75d | 1427d |  |  |  | 1840h | 360h |
| 95 | 1.1.4.2.13.1 | Produce redlines of consensus policy provisions (Item 1) |  | 45d | 2020-08-03 A | 2020-10-02 A |  | 100% |  |  |  | start no earlier than 2020-08-03 | GDS Staff | 360h | 360h |
| 96 | 1.1.4.2.13.2 | Review and confirm redlines for final changes |  | 40d | 2020-10-05 | 2020-11-27 | 95 |  |  | 1427d | 0d |  | GDS Staff; IRT; Policy Staff | 960h |  |
| 97 | 1.1.4.2.13.3 | Conduct public comment of changes |  | 30d | 2020-11-30 | 2021-01-08 | 96 |  |  | 1427d | 0d |  | GDS Staff; IRT | 480h |  |
| 98 | 1.1.4.2.13.4 | Post updated consensus policy |  | 5d | 2021-01-11 | 2021-01-15 | 97 |  |  | 1427d |  |  | GDS Staff | 40h |  |
| 99 | 1.1.4.2.14 | **Uniform Rapid Suspension System Procedure (URS) [HIGH]** |  | 120d | 2021-05-05 A | 2021-10-19 |  | 38% | 75d | 1229d |  |  |  | 1840h | 360h |
| 100 | 1.1.4.2.14.1 | Produce redlines of consensus policy provisions (Items 1,2 & 8) |  | 45d | 2021-05-05 A | 2021-07-06 A | 151 | 100% |  |  |  | start no earlier than 2020-11-02 | GDS Staff | 360h | 360h |
| 101 | 1.1.4.2.14.2 | Review and confirm redlines for final changes |  | 40d | 2021-07-07 | 2021-08-31 | 100 |  |  | 1229d | 0d |  | GDS Staff; IRT; Policy Staff | 960h |  |
| 102 | 1.1.4.2.14.3 | Conduct public comment of changes |  | 30d | 2021-09-01 | 2021-10-12 | 101 |  |  | 1229d | 0d |  | GDS Staff; IRT | 480h |  |
| 103 | 1.1.4.2.14.4 | Post updated consensus policy |  | 5d | 2021-10-13 | 2021-10-19 | 102 |  |  | 1229d |  |  | GDS Staff | 40h |  |

Notes:
- 78: Thick Whois Transition Policy for .COM, .NET, .JOBS / This policy requires that all new domain name registrations must be submitted as thick registrations as of a certain date, and those gTLD registry operators currently providing thin WHOIS services must support thick data for all new registrations as of a certain date. These registries must also migrate all existing domain name registrations to a thick format, which transition is to occur according to a set schedule. While this policy is in effect, its enforcement is deferred pending specified milestones in implementation of the Registration Data Policy. 1. The new Registration Data Policy does not use the terms thin and thick data. Rather, the policy defines data elements to be collected, transferred, and published. The Thick Whois Transition Policy Section 2 references Thin and Thick definitions, which may be eliminated if there is no need for a distinction among these types of registries. / 2.The Thick Whois Transition Policy, section 4, Registry Operator Requirements, notes that, for a period of time, if no data exists in certain fields for existing registrations, these may be treated as optional. The context appears to refer to both transfer and publication, though this is not explicitly stated. Under the new Registration Data Policy, there is a different set of data elements transferred from registrar to registry than is displayed by the registry. If these policy requirements are carried over, this clause should eliminate all Administrative Contact data elements and clarify the requirements for the other elements listed.~ / 3.As noted in the EPDP Teams Phase 1 recommendation 12, it is not contemplated that there will be a means for transfer of consent from registrar to registry. Accordingly, in cases where registries require certain data elements, this transfer could only occur on a legal basis other than consent of the data subject. The result would be that the outputs of various registries would look different based on the registry operators determinations.~ / 4.A key foundation of this policy is the migration of records to occur over time. It is expected that all gTLD registry operators will be required to make changes to their systems to support the updated requirements for the Registration Data Policy, for new and existing registrations. This transition may take different forms depending on the previous requirements each registry operator was following. This policy addresses the specific case of what is necessary for transitioning registrations from a thin to a thick format. If changes are considered to this policy as a result of GNSO policy work, a foundational question is whether a policy is needed to deal with the specific case of com and net registrations under the new Registration Data Policy. TBD Some questions have arisen in the IRT concerning the impact of the phase 1 recommendations on the Thick Whois policy. Those questions should be addressed before further consideration is given to if/how to affect further updates.
- 84: Transfer Policy / This policy aims to provide a straightforward procedure for domain name holders to transfer their names from one ICANN-accredited registrar to another should they wish to do so. The policy provides standardized requirements for registrar handling of transfer requests from domain name holders. The policy also includes procedures covering a change of registrant where a registration remains with the same registrar. 1. Consistency of terminology (WHOIS/RDS/Whois data/Registration data) / 2.Transfer Policy section I.A.1.1 provides that either the Registrant or the Administrative Contact can approve or deny a transfer request. Under the Registration Data Policy, Administrative Contact data is no longer collected by the registrar. Accordingly, the registrant would be the only authorized transfer contact. / 3.Transfer Policy section I.A.3 enumerates the reasons a registrar of record may deny a transfer. These include section 3.7.2, reasonable dispute over the identity of the Registered Name Holder or Administrative Contact. The Administrative Contact reference may be eliminated as the Administrative Contact data is no longer collected by the registrar. Section I.A.3 also enumerates the reasons a registrar of record may not use to deny a transfer request. These include section 3.9.2, no response from the Registered Name Holder or Administrative Contact. The Administrative Contact reference may be eliminated as the Administrative Contact data is no longer collected by the registrar. / 4.Transfer Policy section I.A.5.6 provides that the "AuthInfo" codes must be used solely to identify a Registered Name Holder, whereas the Forms of Authorization (FOAs) still need to be used for authorization or confirmation of a transfer request, as described in Sections I.A.2, I.A.3, and I.A.4 of the policy. Where registrant contact data is not published, and absent an available mechanism for the Gaining Registrar to obtain such contact data, it is not feasible for a Gaining Registrar to send an FOA to the registrant contact data associated with an existing registration, as required by the policy. However, the requirement for the Registrar of Record to send an FOA confirming a transfer request (covered in section I.A.3) is still achievable as the registrar does not need to rely on publicly available data. / 5.Transfer Policy section II.B.1, Availability of Change of Registrant, provides that Registrants must be permitted to update their registration/Whois data and transfer their registration rights to other registrants freely. This language may be updated to clarify what updating registration data means, i.e., whether requirements differ according to whether a change of registrant changes anything that is displayed. / 6.Transfer Policy section II.B.1.1.4 references the Administrative Contact. The context of this provision is to define a change of registrant as a material change to certain fields, including Administrative Contact email address, if there is no Prior Registrant email address. This section may no longer be necessary, as, under the new Registration Data Policy, Administrative Contact data is no longer collected by the registrar. Note, the Council has tasked a Transfer Scoping Team to consider the output from the recent review and make recommendations for how identified issues could / should be addressed. 1. Request EPDP Phase 1 IRT or establish new IRT to address terminology updates / 2.Request EPDP Phase 1 IRT to remove references to Administrative Contact / 3.Request EPDP Phase 1 IRT to remove references to Administrative Contact / 4.Request Transfer Scoping Team to consider this issue as part of its scoping effort / 5.Request Transfer Scoping Team to consider this issue as part of its scoping effort / 6.Request EPDP Phase 1 IRT to remove references to Administrative Contact
- 89: Transfer Dispute Resolution Policy (TDRP) / This policy addresses disputed domain name transfers between registrars, and all ICANN-accredited registrars must abide by its procedures and decisions. 1. Consistency of terminology (WHOIS/RDS/Whois data/Registration data) / 2.TDRP section 3.1.4 (i)(b) references a "copy of Whois output." The context for this provision is a listing of documentary evidence to be annexed to a complaint by the gaining registrar. This requirement may need to be further defined for clarity on what data the registrar must copy and include. Applying the definition of Whois data to have the same meaning as Registration Data as provided in EPDP recommendation 24, this would include all data elements that were collected by the registrar. / 3.TDRP section 3.1.4(ii)(c) enumerates the materials to be annexed to a complaint by the losing registrar. This provision specifies that the losing registrar is expected to provide a history of any Whois registration data changes made to the applicable registration. This requirement may need to be further defined as to what constitutes Whois modifications i.e., changes to public and/or non-public data elements. This provision may also need to be revised to clarify the scope of history available to the registrar, as it can only go as far back as data is retained. If the relevant data retention policy and uses of registration data including TDRP were disclosed to the data subject at the time of registration, this should cover such disclosure within the applicable period. / 4.TDRP section 3.2.4 provides that a panel appointed by a TDRP provider will review all applicable documentation and compare registrant/contact data with that contained within the authoritative Whois database and reach a conclusion not later than thirty (30) days after receipt of Response. This provision relies on comparison with the "authoritative Whois database," which does not have a clear analogue in the new Registration Data Policy. / The purpose of this provision appears to be for the panel to validate the information provided to them by the registrars; however, it is not clear what source a panel would use as a basis for comparison with the registrar submissions under the new policy. The TDRP provides for the panel to match what the registrars provide with its own lookup; this does not seem to be possible unless a) the panel requests non-public data from the registrar in a similar manner as a UDRP provider, which would result in duplicative data or b) the complaint only includes publicly accessible data, and the panel is able to request and obtain the non-public data from the registrar. Registration data held by the registry operator is not referenced in this section except to note that in cases where the Registrar of Record's Whois is not accessible or invalid, the applicable Registry Operator's Whois should be used, except in the case of a thin Registry, in which case the dispute should be placed on hold. It may be necessary to establish what is authoritative and what sources the panel should use in considering a TDRP complaint.~ / Alternatively, the provisions of this section could be restated at a higher level to define what the panel is being asked to do. The specific steps regarding comparison of various registration data sources may not be the basis for the panels determination; rather, the panel is asked to consider the facts and circumstances and evidence presented by the parties to the dispute to determine whether a violation of the Transfer Policy has occurred. 1. Request EPDP Phase 1 IRT or establish new IRT to address terminology updates / 2.Request Transfer Scoping Team to consider this issue as part of its scoping effort / 3.Request Transfer Scoping Team to consider this issue as part of its scoping effort / 4.Request Transfer Scoping Team to consider this issue as part of its scoping effort
- 94: Rules for Uniform Domain Name Dispute Resolution Policy (UDRP Rules) / The UDRP Rules provide the baseline procedural requirements that must be followed for each stage of a dispute resolution administrative proceeding, such as required notice to a Respondent, time for filing a response, and appointment of the administrative panel for a UDRP proceeding. 1. Consistency of terminology (WHOIS/RDS/Whois data/Registration data) / 2.UDRP Rules sections 1 and 2 reference the Whois database. The context of this provision is a definition for Mutual Jurisdiction, noting that this refers to either (a) the principal office of the registrar, or (b) the domain-name holder's address as shown in the Registrar's Whois database at the time the complaint is submitted, as appropriate. If changes are considered to these rules as a result of GNSO policy work, it may be beneficial to update this terminology to specify the intended source of the registrants address. / 3.UDRP Rules section 1 includes definitions of terms used. If changes are considered to these rules as a result of GNSO policy work, it may be beneficial to update this to include the term and definition for Registration Data Directory Services. / 4.UDRP Rules section 2(a)(i) and 2(a)(ii)(A) include references to the Administrative Contact. The context of this provision is the UDRP providers responsibility to use available means to achieve notice when notifying a registrant that a UDRP complaint has been filed. The references to Administrative Contact can be removed without altering the substance of the requirement. / 5.Also in UDRP Rules section 2, the stated principle is that it shall be the Provider's responsibility to employ reasonably available means calculated to achieve actual notice to Respondent. Given this aim, it may be beneficial to clarify that the Provider should continue to send the notice to all contacts publicly available in RDDS, and also to note that, per EPDP Recommendation 23, the UDRP provider may also request non-public registration data from the registrar, which may aid the provider in enabling the notification to the registrant. / 6.UDRP Rules section 3(b) describes the required elements for submission of a complaint under the UDRP. These include, in item (v), the name of the Respondent (domain-name holder) and all information (including any postal and email addresses and telephone and telefax numbers) known to Complainant regarding how to contact Respondent or any representative of Respondent, including contact information based on pre-complaint dealings, in sufficient detail to allow the Provider to send the complaint as described in Paragraph 2(a). Per the EPDP Teams Phase 1 recommendation 23, this provision may be updated to clarify that a complaint will not be deemed administratively deficient for failure to provide the name of the Respondent and all other relevant contact information. / 7.Current practices relating to amending a UDRP complaint vary. In one instance, a provider requires the complainant to amend its complaint to reflect the registrant information received from the registrar so that the proceeding can go forward. If the complainant does not amend the complaint, the UDRP complaint is dismissed. In another, a provider strongly encourages the complainant to amend its complaint, however, a complainants failure to do so would not be treated as a formal deficiency under the UDRP Rules. This process may benefit from some clarification to ensure consistency among UDRP providers. / The EPDP Teams recommendation 21 provides that: ... the GNSO Council instructs the review of all RPMs PDP WG to consider, as part of its deliberations, whether there is a need to update existing requirements to clarify that a complainant must only be required to insert the publicly-available RDDS data for the domain name(s) at issue in its initial complaint. The EPDP Team also recommends the GNSO Council to instruct the RPMs PDP WG to consider whether upon receiving updated RDDS data (if any), the complainant must be given the opportunity to file an amended complaint containing the updated respondent information / 8.UDRP Rules section 4 provides that a UDRP provider submits a verification request to the registrar for the domain name(s) that are the subject of the complaint, which verification request includes a request to lock the domain name registration. Per EPDP recommendation 23, this provision may be updated to clarify that along with the verification request, the provider may also request the non-public registration data for each of the specified domain names, which shall be provided to the provider upon its notifying the Registrar of the existence of a UDRP complaint. / 9.UDRP Rules section 16(b) require the panel to publish the full decision and the date of implementation on a publicly accessible website, as well as the portion of any decision determining a complaint to have been brought in bad faith. Concerning the publication of decisions, it may be useful to reference Purpose 6-PA5 in the Final EPDP report regarding publication of registration data elements used for complaints on Dispute Resolution Provider websites. / 10.UDRP Rules section 21 provides for amendments to the rules, noting that The version of these Rules in effect at the time of the submission of the complaint to the Provider shall apply to the administrative proceeding commenced thereby. These Rules may not be amended without the express written approval of ICANN.~ / 11.Feedback from some stakeholders in June 2019 during an ICANN65 session noted the work plans of the RPM PDP Working Group, but posed the question of whether there were some procedural quick fixes to the UDRP Rules that could be adopted without waiting for the policy development process to complete. The GNSO may wish to consider this feedback in determining next steps. 1. Request EPDP Phase 1 IRT or establish new IRT to address terminology updates / 2-11Request RPM Phase 2 to consider these items
- 99: Uniform Rapid Suspension System Procedure (URS) / The Procedure explains how to file a URS claim against a domain name registration, including fees, filing requirements, and steps involved in the process. 1. Consistency of terminology (WHOIS/RDS/Whois data/Registration data) / 2.URS section 1.2 includes various references to Whois. The context of this provision is a description of the contents of a complaint submitted to a URS provider. References include section 1.2.3, describing Name of Registrant and available contact information available in Whois. Section 1.2.4 requires inclusion of the specific domain names that are the subject of the complaint, accompanied by a copy of the currently available Whois information.~ / 3.URS section 1.2 provides that a service provider make space in the complaint form for the enumerated information associated with the URS complaint. Per the EPDP Teams Phase 1 recommendation 23, this provision may be updated to clarify that a complaint will not be deemed administratively deficient for failure to provide the name of the Respondent and all other relevant contact information. / 4.URS section 3.3 provides that Given the rapid nature of this Procedure, and the intended low level of required fees, there will be no opportunity to correct inadequacies in the filing requirements. / URS section 3.4 provides that if a Complaint is deemed non-compliant with filing requirements, the Complaint will be dismissed without prejudice to the Complainant filing a new complaint. The initial filing fee shall not be refunded in these circumstances. This provision may be modified to clarify that a Complainant's complaint will not be deemed administratively deficient for failure to provide the name of the Respondent and all other relevant contact information. / A question to consider is whether URS sections 3.3 and 3.4 should be updated to allow for amendment of a URS Complaint. Per the EPDP Teams Phase 1 recommendation 21, the GNSO Council instructs the review of all Review of All Rights Protection Mechanisms in All gTLDs (RPMs) PDP Working Group to consider whether (a) there is a need to update existing requirements to clarify that a complainant must only be required to insert the publicly-available RDDS data for the domain name(s) at issue in its initial complaint, and (b) upon receiving updated RDDS data (if any), the complainant must be given the opportunity to file an amended complaint containing the updated respondent information. / 5.URS section 4 describes requirements for notice and locking of a domain name. Section 4.2 notes that, within 24 hours after receiving a Notice of Lock from the registry operator, a URS provider notifies the registrant of the complaint by sending a hard copy to the addresses listed in the Whois contact information. This may be revised to clarify that the provider should continue to send the notice to all contacts publicly available in RDDS; however, along with the Notice of Lock, the Provider may also request the non-public registration data for each of the specified domain names from the registrar, which shall be provided to the Provider upon the Provider notifying the Registry or Registrar of the existence of a complaint. / 6.URS section 6 contains a procedure for default cases. Section 6.2 requires that During the Default period, the Registrant will be prohibited from changing content found on the site to argue that it is now a legitimate use and will also be prohibited from changing the Whois information. Updates to this section may be considered to provide clarity on the information that may not be changed by a registrant, i.e., public and non-public data elements. / 7.URS section 9.4 requires that Determinations resulting from URS proceedings will be published by the URS Provider on the Providers website in accordance with the Rules. Concerning the publication of decisions, it may be useful to reference Purpose 6-PA5 in the Final EPDP report regarding publication of registration data elements used for complaints on Dispute Resolution Provider websites to Internet users. / 8.URS section 10.2 requires that The Whois for the domain name shall continue to display all of the information of the original Registrant except for the redirection of the nameservers. In addition, the Registry Operator shall cause the Whois to reflect that the domain name will not be able to be transferred, deleted or modified for the life of the registration This language may be updated to refer to registration data rather than Whois. / 9.Feedback from some stakeholders in June 2019 during an ICANN65 session noted the work plans of the RPM PDP Working Group, but posed the question of whether there were some procedural quick fixes to the UDRP and URS that could be adopted without waiting for the policy development process to complete. The GNSO may wish to consider this feedback in determining next steps. 1. Request EPDP Phase 1 IRT or establish new IRT to address terminology updates / 2-9 Consult with the RPM PDP WG to determine which, if any, of these items have already been addressed, or could be easily addressed, without compromising the timeline. Based on feedback, determine appropriate next steps.

| ID | WBS | Task | Type | Duration | Start | Finish | Predecessors | Complete | Remaining | Total slack | Free slack | Constraint | Resources | Work | Actual work |
| --- | --- | --- | --- | --- | --- | --- | --- | --- | --- | --- | --- | --- | --- | --- | --- |
| 104 | 1.1.4.2.15 | **Uniform Rapid Suspension System Rules (URS Rules) [HIGH]** |  | 120d | 2021-05-05 A | 2021-10-19 |  | 38% | 75d | 1229d |  |  |  | 1840h | 360h |
| 105 | 1.1.4.2.15.1 | Produce redlines of consensus policy provisions (Items 1&3) |  | 45d | 2021-05-05 A | 2021-07-06 A | 151 | 100% |  |  |  | start no earlier than 2020-11-02 | GDS Staff | 360h | 360h |
| 106 | 1.1.4.2.15.2 | Review and confirm redlines for final changes |  | 40d | 2021-07-07 | 2021-08-31 | 105 |  |  | 1229d | 0d |  | GDS Staff; IRT; Policy Staff | 960h |  |
| 107 | 1.1.4.2.15.3 | Conduct public comment of changes |  | 30d | 2021-09-01 | 2021-10-12 | 106 |  |  | 1229d | 0d |  | GDS Staff; IRT | 480h |  |
| 108 | 1.1.4.2.15.4 | Post updated consensus policy |  | 5d | 2021-10-13 | 2021-10-19 | 107 |  |  | 1229d |  |  | GDS Staff | 40h |  |
| 109 | 1.1.4.2.16 | **Whois Data Reminder Policy (WDRP) [MEDIUM]** |  | 297d | 2020-09-04 A | 2021-10-22 |  | 37% | 186.55d | 1226d |  |  |  | 1856h | 360h |
| 110 | 1.1.4.2.16.1 | **Track 1 - Item 1** |  | 120d | 2020-09-04 A | 2021-02-18 |  | 38% | 75d | 1403d |  |  |  | 1840h | 360h |
| 111 | 1.1.4.2.16.1.1 | Produce redlines of consensus policy provisions | manual | 45d | 2020-09-04 A | 2020-11-05 A |  | 100% |  |  |  |  | GDS Staff | 360h | 360h |
| 112 | 1.1.4.2.16.1.2 | Review and confirm redlines for final changes |  | 40d | 2020-11-06 | 2020-12-31 | 111 |  |  | 1403d | 0d |  | GDS Staff; IRT; Policy Staff | 960h |  |
| 113 | 1.1.4.2.16.1.3 | Conduct public comment of changes |  | 30d | 2021-01-01 | 2021-02-11 | 112 |  |  | 1403d | 0d |  | GDS Staff; IRT | 480h |  |
| 114 | 1.1.4.2.16.1.4 | Post updated consensus policy |  | 5d | 2021-02-12 | 2021-02-18 | 113 |  |  | 1403d |  |  | GDS Staff | 40h |  |
| 115 | 1.1.4.2.16.2 | **Track 2 - Items 2 through 6** |  | 1d | 2021-10-22 | 2021-10-22 |  |  |  | 0d |  |  |  | 16h |  |
| 116 | 1.1.4.2.16.2.1 | Migrated to Remaining EPDP-P2 Topics Track 2 (Accuracy) | manual | 1d | 2021-10-22 | 2021-10-22 | 19 |  |  |  |  |  | Policy Staff; Council | 16h |  |
| 117 | 1.1.4.2.17 | **Whois Marketing Restriction Policy [LOW]** |  | 120d | 2020-09-04 A | 2021-02-18 |  | 38% | 75d | 1403d |  |  |  | 1840h | 360h |
| 118 | 1.1.4.2.17.1 | Produce redlines of consensus policy provisions | manual | 45d | 2020-09-04 A | 2020-11-05 A |  | 100% |  |  |  |  | GDS Staff | 360h | 360h |
| 119 | 1.1.4.2.17.2 | Review and confirm redlines for final changes |  | 40d | 2020-11-06 | 2020-12-31 | 118 |  |  | 1403d | 0d |  | GDS Staff; IRT; Policy Staff | 960h |  |
| 120 | 1.1.4.2.17.3 | Conduct public comment of changes |  | 30d | 2021-01-01 | 2021-02-11 | 119 |  |  | 1403d | 0d |  | GDS Staff; IRT | 480h |  |
| 121 | 1.1.4.2.17.4 | Post updated consensus policy |  | 5d | 2021-02-12 | 2021-02-18 | 120 |  |  | 1403d |  |  | GDS Staff | 40h |  |
| 122 | 1.1.5 | **Revised ICANN Procedure for Handling Whois Conflicts with Privacy Law** |  | 605d | 2020-07-31 A | 2022-11-22 |  | 10% | 545d | 943d |  |  |  | 10000h | 960h |
| 123 | 1.1.5.1 | Council small scoping team to determine next steps and Council consideration | manual | 60d | 2020-07-31 A | 2020-10-22 A |  | 100% |  |  |  |  | Council; Policy Staff | 960h | 960h |
| 124 | 1.1.5.2 | Request ICANN org to develop revised proposal for invoking Procedure |  | 90d | 2020-10-23 | 2021-02-25 | 123 |  |  | 943d | 0d |  | GDS Staff; Policy Staff; Legal Staff | 2160h |  |
| 125 | 1.1.5.3 | Council to deliberate findings and determine appropriate path |  | 45d | 2021-02-26 | 2021-04-28 | 124 |  |  | 943d | 0d |  | Council; Policy Staff | 720h |  |
| 126 | 1.1.5.4 | IF required, review WPIAG Charter to determine if it's fit for purpose |  | 30d | 2021-04-29 | 2021-06-09 | 125 |  |  | 943d | 0d |  | Council; Policy Staff | 480h |  |
| 127 | 1.1.5.5 | **IF required, Council to approve charter and launch WPIAG** |  | 105d | 2021-06-10 | 2021-11-02 |  |  |  | 943d |  |  |  | 1680h |  |
| 128 | 1.1.5.5.1 | Engage WPIAG |  | 60d | 2021-06-10 | 2021-09-01 | 126 |  |  | 943d | 0d |  | Policy Staff; Working Group | 960h |  |
| 129 | 1.1.5.5.2 | Council to deliberate findings and determine appropriate path |  | 45d | 2021-09-02 | 2021-11-02 | 128 |  |  | 943d | 0d |  | Council; Policy Staff | 720h |  |

Notes:
- 104: Uniform Rapid Suspension System Rules (URS Rules) / The URS Rules describe how service providers will implement the URS in a consistent manner./ 1. Consistency of terminology (WHOIS/RDS/Whois data/Registration data) / 2.URS Rules section 1 includes definitions of terms used. If changes are considered to these rules as a result of GNSO policy work, it may be beneficial to update this to include the term and definition for Registration Data Directory Services./ 3.URS Rules section 2(a)(i) includes references to the Administrative Contact. The context of this provision is the UDRP providers responsibility to use available means to achieve notice when notifying a registrant that a UDRP complaint has been filed. The references to Administrative Contact can be removed without altering the substance of the requirement. / 4.Also in URS Rules section 2(a), the stated principle is that, when forwarding a complaint, it shall be the Provider's responsibility to employ reasonably available means calculated to achieve actual notice to Respondent. Given this aim, it may be beneficial to clarify that the Provider should continue to send the notice to all contacts publicly available in RDDS, and also to note that, per EPDP recommendation 23, the provider may also request non-public registration data from the registrar, which may aid the provider in enabling the notification to the registrant. / 5.URS Rules section 3(b)(iv) require a complaint to include the domain name(s) that are the subject of the Complaint and a copy of the currently available Whois information. This may be updated to clarify that a complaint will not be deemed administratively deficient for failure to provide the name of the Respondent and all other relevant contact information. / 6.URS Rules 4(b) provide that the Notice of Complaint sent to the registrant shall be transmitted in English and translated by the provider into the predominant language used in the registrants country or territory, as determined by the country(ies) listed in the Whois record when the Complaint is filed. This provision may not be affected by the new Registration Data Policy because the country field is still publicly displayed. With regard to 4(b), it may be beneficial to clarify that the provider may also request non-public registration data from the registrar upon presentation of a complaint. / 7.URS Rules section 15.4 requires that, with certain exceptions, the Provider shall publish the Determination and the date of implementation on a publicly accessible web site. Concerning the publication of decisions, it may be useful to reference Purpose 6-PA5 in the Final EPDP report regarding publication of registration data elements used for complaints on Dispute Resolution Provider websites to Internet users. / 8.Many of the points discussed here mirror those discussed in the URS Procedure analysis, above. If changes are considered to these rules as a result of GNSO policy work, it may be beneficial to more clearly differentiate the content of the procedure and the rules to avoid redundancies. 1. Request EPDP Phase 1 IRT or establish new IRT to address terminology updates / 2.Consult with the RPM PDP WG to determine which, if this item has already been addressed, or could be easily addressed, without compromising the timeline. Based on feedback, determine appropriate next steps / 3.Request EPDP Phase 1 IRT or establish new IRT to address removal of reference to administrative contact / 4-8 Consult with the RPM PDP WG to determine which, if this item has already been addressed, or could be easily addressed, without compromising the timeline. Based on feedback, determine appropriate next steps
- 109: Whois Data Reminder Policy (WDRP) / At least annually, a registrar must present to the registrant the current Whois information for each domain name registration, and remind the registrant that provision of false Whois information can be grounds for cancellation of the domain name registration. Registrants must review their Whois data, and make any corrections. 1. Consistency of terminology (WHOIS/RDS/Whois data/Registration data) / 2.Per the EPDP Teams Phase 1 recommendation 4, requirements related to the accuracy of registration data under the current ICANN contracts and consensus policies shall not be affected by this policy. The policy would accordingly be expected remain in place; however, some clarifications may be needed to harmonize the WDRP policy requirements with the new Registration Data Policy requirements. / 3.In considering how such requirements carry over to the new policy environment, this analysis relies on the definition of Registration Data in section 2 of the Temporary Specification, namely, "Registration Data" means data collected from a natural and legal person in connection with a domain name registration. Accordingly, to meet the policy objective, the requirement would be for the notice to contain the data that is collected by the registrar. / 4.The Registration Data Policy does not speak to whether optional data elements should be included in the WDRP notice; however, under the definition of Registration Data above, optional elements are part of the data collected by the registrar and thus should be included, supporting the policy goal of enabling the registrant to keep its information current. / 5.It should be noted that the WDRP text consists of only two sentences, followed by several Notes sections. If additional policy work is pursued by the GNSO to update this policy, ICANN org would recommend additional changes to the Notes accompanying the policy with the GNSOs acknowledgement of such, for example, the WDRP section on Time for Coming into Compliance may be eliminated as obsolete. / 6.The policy is accompanied by a model WDRP notice that includes Administrative Contact, Technical Contact, and Registrant Organization. If updates to the model notice are being considered as a result of GNSO policy work, it may be beneficial to clarify that the notice should contain the elements that are required to be collected by the Registration Data Policy. Additionally, if changes are considered to the model notice as a result of GNSO policy work, the contact information shown for the ICANN organization example needs to be updated. The Registration Data Policy does not appear to preclude registrars from adding more data elements to the notice than are included in the model notice; this point may be clarified. Note, this policy has never been reviewed. Noting the issues identified, it may benefit from an overall review following which the Council could decide whether to initiate a PDP or follow another path to effectuate changes. 1. Request EPDP Phase 1 IRT or establish new IRT to address terminology updates / 2-6Request GDD staff to prepare a Policy Status Report which, amongst others, will include this issues, following which the Council will determine the most appropriate path to pursue.
- 117: Whois Marketing Restriction Policy / This policy is a revision to the third-party bulk access provisions in ICANN's 2001 Registrar Accreditation Agreement to restrict the use of WHOIS data for marketing and re-use. 1. Consistency of terminology (WHOIS/RDS/Whois data/Registration data) 1. Request EPDP Phase 1 IRT or establish new IRT to address terminology updates
- 122: https://docs.google.com/document/d/1V7zFndE8kenWLCRgGXijXiIpF8Qf7m-v586VQMDE1QY/edit

| ID | WBS | Task | Type | Duration | Start | Finish | Predecessors | Complete | Remaining | Total slack | Free slack | Constraint | Resources | Work | Actual work |
| --- | --- | --- | --- | --- | --- | --- | --- | --- | --- | --- | --- | --- | --- | --- | --- |
| 130 | 1.1.5.6 | **IF required, Council to approve launch of EPDP** |  | 275d | 2021-11-03 | 2022-11-22 |  |  |  | 943d |  |  |  | 4000h |  |
| 131 | 1.1.5.6.1 | Engage EPDP: Temporary Specification on gTLD Registration Data - Phase 2 |  | 90d | 2021-11-03 | 2022-03-08 | 129 |  |  | 943d | 0d |  | Policy Staff; Working Group | 1440h |  |
| 132 | 1.1.5.6.2 | Council to deliberate and adopt working group consensus recommendations |  | 45d | 2022-03-09 | 2022-05-10 | 131 |  |  | 943d | 0d |  | Council; Policy Staff | 720h |  |
| 133 | 1.1.5.6.3 | Board to deliberate and adopt consensus recommendations |  | 50d | 2022-05-11 | 2022-07-19 | 132 |  |  | 943d | 0d |  | Board | 400h |  |
| 134 | 1.1.5.6.4 | Engage IRT: Temporary Specification on gTLD Registration Data - Phase 2 |  | 90d | 2022-07-20 | 2022-11-22 | 133 |  |  | 943d |  |  | GDS Staff; Policy Staff | 1440h |  |
| 135 | 1.1.6 | **EPDP-P1 Rec27 Wave 1.5 & Wave 2 Other Policy Impacts (pending delivery)** |  | 165d | 2020-12-17 | 2021-08-03 |  |  |  | 0d |  |  |  | 4320h |  |
| 136 | 1.1.6.1 | Council to consider Wave 1.5 report and determine next steps | manual | 90d | 2020-12-17 | 2021-04-20 |  |  |  |  |  |  | GDS Staff; Council; Policy Staff | 2160h |  |
| 137 | 1.1.6.2 | Council to consider Wave Wave 2 reports and determine next steps | manual | 90d | 2021-03-31 | 2021-08-03 |  |  |  |  |  |  | GDS Staff; Council; Policy Staff | 2160h |  |
| 138 | 1.1.7 | **IRT: Privacy & Proxy Services Accreditation Issues (on-hold pending EPDP)** |  | 270d | 2021-01-22 | 2022-02-01 |  |  |  | 1153d |  |  |  | 6480h |  |
| 139 | 1.1.7.1 | Engage IRT: Privacy & Proxy Services Accreditation Issues |  | 270d | 2021-01-22 | 2022-02-01 | 5 |  |  | 1153d |  | start no earlier than 2021-01-22 | GDS Staff; IRT; Policy Staff | 6480h |  |
| 140 | 1.1.8 | **IRT: Translation/Transliteration of gTLD Registration Data (on-hold pending EPDP + RDAP)** |  | 270d | 2021-01-22 | 2022-02-01 |  |  |  | 1153d |  |  |  | 6480h |  |
| 141 | 1.1.8.1 | Engage IRT: Translation/Transliteration of gTLD Registration Data |  | 270d | 2021-01-22 | 2022-02-01 | 5 |  |  | 1153d |  | start no earlier than 2021-01-22 | GDS Staff; IRT; Policy Staff | 6480h |  |
| 142 | 1.2 | **RPM - Program Track** |  | 1145d | 2020-07-01 A | 2024-11-13 |  | 17% | 952.41d | 425d |  |  |  | 29424h | 4384h |
| 143 | 1.2.1 | **PDP: Review of All Rights Protection Mechanisms in All gTLDs - Phase 1 (URS, TMCH, Sunrise, Claims)** |  | 490d | 2020-07-01 A | 2022-05-13 |  | 43% | 281.52d | 1080d |  |  |  | 11984h | 4384h |
| 144 | 1.2.1.1 | Engage Phase 1 working group (started 4 Mar 2016) |  | 120d | 2020-07-01 A | 2020-12-15 A |  | 100% |  |  |  |  | Working Group; Policy Staff | 1920h | 1920h |
| 145 | 1.2.1.2 | **EPDP-P1 Rec27 Wave 1 Other Policy Impacts** |  | 77d | 2020-07-01 A | 2020-10-15 A |  | 100% |  |  |  |  |  | 2464h | 2464h |
| 146 | 1.2.1.2.1 | **Track 2 - URS - Items 3 through 7** |  | 77d | 2020-07-01 A | 2020-10-15 A |  | 100% |  |  |  |  |  | 1232h | 1232h |
| 147 | 1.2.1.2.1.1 | Determine if or easily can be addressed, else report back to Council |  | 77d | 2020-07-01 A | 2020-10-15 A |  | 100% |  |  |  |  | Policy Staff; Working Group | 1232h | 1232h |
| 148 | 1.2.1.2.2 | **Track 2 - URS Rules - Items 2, 4 through 8** |  | 77d | 2020-07-01 A | 2020-10-15 A |  | 100% |  |  |  |  |  | 1232h | 1232h |
| 149 | 1.2.1.2.2.1 | Determine if or easily can be addressed, else report back to Council |  | 77d | 2020-07-01 A | 2020-10-15 A |  | 100% |  |  |  |  | Policy Staff; Working Group | 1232h | 1232h |
| 150 | 1.2.1.3 | Council to deliberate and adopt working group consensus recommendations |  | 40d | 2020-12-16 | 2021-02-09 | 144, 147, 149 |  |  | 425d | 0d |  | Council; Policy Staff | 640h |  |
| 151 | 1.2.1.4 | Board to deliberate and adopt consensus recommendations |  | 60d | 2021-02-10 | 2021-05-03 | 150 |  |  | 1080d | 0d |  | Board | 480h |  |
| 152 | 1.2.1.5 | Engage IRT |  | 270d | 2021-05-04 | 2022-05-13 | 151 |  |  | 1080d |  |  | IRT; GDS Staff; Policy Staff | 6480h |  |
| 153 | 1.2.2 | **PDP: Review of All Rights Protection Mechanisms in All gTLDs - Phase 2 (UDRP)** |  | 985d | 2021-02-10 | 2024-11-13 |  |  |  | 425d |  |  |  | 17440h |  |
| 154 | 1.2.2.1 | Drafting Team to draft new charter (incl. Items 2 through 11 of Rec27 Wave1) |  | 90d | 2021-02-10 | 2021-06-14 | 150 |  |  | 425d | 0d |  | Council; Policy Staff | 1440h |  |
| 155 | 1.2.2.2 | Engage Phase 2 working group |  | 525d | 2021-06-15 | 2023-06-15 | 154 |  |  | 425d | 0d |  | Working Group; Policy Staff | 8400h |  |
| 156 | 1.2.2.3 | Council to deliberate and adopt working group consensus recommendations |  | 40d | 2023-06-16 | 2023-08-09 | 155 |  |  | 425d | 0d |  | Council; Policy Staff | 640h |  |
| 157 | 1.2.2.4 | Board to deliberate and adopt consensus recommendations |  | 60d | 2023-08-10 | 2023-11-01 | 156 |  |  | 425d | 0d |  | Board | 480h |  |
| 158 | 1.2.2.5 | Engage IRT |  | 270d | 2023-11-02 | 2024-11-13 | 157 |  |  | 425d |  |  | IRT; GDS Staff; Policy Staff | 6480h |  |

Notes:
- 146: Uniform Rapid Suspension System Procedure (URS) / The Procedure explains how to file a URS claim against a domain name registration, including fees, filing requirements, and steps involved in the process. 1. Consistency of terminology (WHOIS/RDS/Whois data/Registration data) / 2.URS section 1.2 includes various references to Whois. The context of this provision is a description of the contents of a complaint submitted to a URS provider. References include section 1.2.3, describing Name of Registrant and available contact information available in Whois. Section 1.2.4 requires inclusion of the specific domain names that are the subject of the complaint, accompanied by a copy of the currently available Whois information.~ / 3.URS section 1.2 provides that a service provider make space in the complaint form for the enumerated information associated with the URS complaint. Per the EPDP Teams Phase 1 recommendation 23, this provision may be updated to clarify that a complaint will not be deemed administratively deficient for failure to provide the name of the Respondent and all other relevant contact information. / 4.URS section 3.3 provides that Given the rapid nature of this Procedure, and the intended low level of required fees, there will be no opportunity to correct inadequacies in the filing requirements. / URS section 3.4 provides that if a Complaint is deemed non-compliant with filing requirements, the Complaint will be dismissed without prejudice to the Complainant filing a new complaint. The initial filing fee shall not be refunded in these circumstances. This provision may be modified to clarify that a Complainant's complaint will not be deemed administratively deficient for failure to provide the name of the Respondent and all other relevant contact information. / A question to consider is whether URS sections 3.3 and 3.4 should be updated to allow for amendment of a URS Complaint. Per the EPDP Teams Phase 1 recommendation 21, the GNSO Council instructs the review of all Review of All Rights Protection Mechanisms in All gTLDs (RPMs) PDP Working Group to consider whether (a) there is a need to update existing requirements to clarify that a complainant must only be required to insert the publicly-available RDDS data for the domain name(s) at issue in its initial complaint, and (b) upon receiving updated RDDS data (if any), the complainant must be given the opportunity to file an amended complaint containing the updated respondent information. / 5.URS section 4 describes requirements for notice and locking of a domain name. Section 4.2 notes that, within 24 hours after receiving a Notice of Lock from the registry operator, a URS provider notifies the registrant of the complaint by sending a hard copy to the addresses listed in the Whois contact information. This may be revised to clarify that the provider should continue to send the notice to all contacts publicly available in RDDS; however, along with the Notice of Lock, the Provider may also request the non-public registration data for each of the specified domain names from the registrar, which shall be provided to the Provider upon the Provider notifying the Registry or Registrar of the existence of a complaint. / 6.URS section 6 contains a procedure for default cases. Section 6.2 requires that During the Default period, the Registrant will be prohibited from changing content found on the site to argue that it is now a legitimate use and will also be prohibited from changing the Whois information. Updates to this section may be considered to provide clarity on the information that may not be changed by a registrant, i.e., public and non-public data elements. / 7.URS section 9.4 requires that Determinations resulting from URS proceedings will be published by the URS Provider on the Providers website in accordance with the Rules. Concerning the publication of decisions, it may be useful to reference Purpose 6-PA5 in the Final EPDP report regarding publication of registration data elements used for complaints on Dispute Resolution Provider websites to Internet users. / 8.URS section 10.2 requires that The Whois for the domain name shall continue to display all of the information of the original Registrant except for the redirection of the nameservers. In addition, the Registry Operator shall cause the Whois to reflect that the domain name will not be able to be transferred, deleted or modified for the life of the registration This language may be updated to refer to registration data rather than Whois. / 9.Feedback from some stakeholders in June 2019 during an ICANN65 session noted the work plans of the RPM PDP Working Group, but posed the question of whether there were some procedural quick fixes to the UDRP and URS that could be adopted without waiting for the policy development process to complete. The GNSO may wish to consider this feedback in determining next steps. 1. Request EPDP Phase 1 IRT or establish new IRT to address terminology updates / 2-9 Consult with the RPM PDP WG to determine which, if any, of these items have already been addressed, or could be easily addressed, without compromising the timeline. Based on feedback, determine appropriate next steps.
- 148: Uniform Rapid Suspension System Rules (URS Rules) / The URS Rules describe how service providers will implement the URS in a consistent manner./ 1. Consistency of terminology (WHOIS/RDS/Whois data/Registration data) / 2.URS Rules section 1 includes definitions of terms used. If changes are considered to these rules as a result of GNSO policy work, it may be beneficial to update this to include the term and definition for Registration Data Directory Services./ 3.URS Rules section 2(a)(i) includes references to the Administrative Contact. The context of this provision is the UDRP providers responsibility to use available means to achieve notice when notifying a registrant that a UDRP complaint has been filed. The references to Administrative Contact can be removed without altering the substance of the requirement. / 4.Also in URS Rules section 2(a), the stated principle is that, when forwarding a complaint, it shall be the Provider's responsibility to employ reasonably available means calculated to achieve actual notice to Respondent. Given this aim, it may be beneficial to clarify that the Provider should continue to send the notice to all contacts publicly available in RDDS, and also to note that, per EPDP recommendation 23, the provider may also request non-public registration data from the registrar, which may aid the provider in enabling the notification to the registrant. / 5.URS Rules section 3(b)(iv) require a complaint to include the domain name(s) that are the subject of the Complaint and a copy of the currently available Whois information. This may be updated to clarify that a complaint will not be deemed administratively deficient for failure to provide the name of the Respondent and all other relevant contact information. / 6.URS Rules 4(b) provide that the Notice of Complaint sent to the registrant shall be transmitted in English and translated by the provider into the predominant language used in the registrants country or territory, as determined by the country(ies) listed in the Whois record when the Complaint is filed. This provision may not be affected by the new Registration Data Policy because the country field is still publicly displayed. With regard to 4(b), it may be beneficial to clarify that the provider may also request non-public registration data from the registrar upon presentation of a complaint. / 7.URS Rules section 15.4 requires that, with certain exceptions, the Provider shall publish the Determination and the date of implementation on a publicly accessible web site. Concerning the publication of decisions, it may be useful to reference Purpose 6-PA5 in the Final EPDP report regarding publication of registration data elements used for complaints on Dispute Resolution Provider websites to Internet users. / 8.Many of the points discussed here mirror those discussed in the URS Procedure analysis, above. If changes are considered to these rules as a result of GNSO policy work, it may be beneficial to more clearly differentiate the content of the procedure and the rules to avoid redundancies. 1. Request EPDP Phase 1 IRT or establish new IRT to address terminology updates / 2.Consult with the RPM PDP WG to determine which, if this item has already been addressed, or could be easily addressed, without compromising the timeline. Based on feedback, determine appropriate next steps / 3.Request EPDP Phase 1 IRT or establish new IRT to address removal of reference to administrative contact / 4-8 Consult with the RPM PDP WG to determine which, if this item has already been addressed, or could be easily addressed, without compromising the timeline. Based on feedback, determine appropriate next steps

| ID | WBS | Task | Type | Duration | Start | Finish | Predecessors | Complete | Remaining | Total slack | Free slack | Constraint | Resources | Work | Actual work |
| --- | --- | --- | --- | --- | --- | --- | --- | --- | --- | --- | --- | --- | --- | --- | --- |
| 159 | 1.3 | **gTLD - Program Track** |  | 814d | 2020-07-01 A | 2023-08-08 |  | 11% | 723.71d | 756d |  |  |  | 43344h | 4310.4h |
| 160 | 1.3.1 | **CCWG: New gTLD Auction Proceeds Drafting Team (group completed 31 May 2020)** |  | 390d | 2020-08-03 A | 2022-01-26 |  | 6% | 365.5d | 1157d |  |  |  | 5280h | 356h |
| 161 | 1.3.1.1 | Council to deliberate and adopt CCWG recommendations | manual | 20d | 2020-08-03 A | 2020-08-28 A |  | 100% |  |  |  |  | Council; Policy Staff | 320h | 320h |
| 162 | 1.3.1.2 | Board to deliberate and adopt consensus recommendations |  | 120d | 2020-08-31 A | 2021-02-12 | 161 | 4% | 115.5d | 1157d | 0d |  | Board | 960h | 36h |
| 163 | 1.3.1.3 | Implement program |  | 250d | 2021-02-15 | 2022-01-26 | 162 |  |  | 1157d |  |  | Legal Staff; Finance Staff | 4000h |  |
| 164 | 1.3.2 | **PDP: New gTLD Subsequent Procedures PDP** |  | 814d | 2020-07-01 A | 2023-08-08 |  | 13% | 708.6d | 756d |  |  |  | 16624h | 1686.4h |
| 165 | 1.3.2.1 | Execute New gTLD Subsequent Procedures PDP (started 21 Jan 2016) |  | 124d | 2020-07-01 A | 2020-12-21 |  | 85% | 18.6d | 756d | 0d |  | Working Group; Policy Staff | 1984h | 1686.4h |
| 166 | 1.3.2.2 | Council to deliberate and adopt working group recommendations |  | 60d | 2020-12-22 | 2021-03-15 | 165 |  |  | 756d | 0d |  | Council; Policy Staff | 960h |  |
| 167 | 1.3.2.3 | Board to deliberate and adopt consensus recommendations |  | 90d | 2021-03-16 | 2021-07-16 | 166 |  |  | 756d | 0d |  | Board | 720h |  |
| 168 | 1.3.2.4 | Execute IRT |  | 540d | 2021-07-19 | 2023-08-08 | 167 |  |  | 756d |  |  | IRT; GDS Staff; Policy Staff | 12960h |  |
| 169 | 1.3.3 | **Internationalized Domain Names** |  | 770d | 2020-07-01 A | 2023-06-08 |  | 11% | 682.33d | 800d |  |  |  | 21440h | 2268h |
| 170 | 1.3.3.1 | **IDN Operational Track 1 Working Group** |  | 180d | 2020-08-03 A | 2021-04-08 |  | 27% | 132d | 1367d |  |  |  | 2880h | 768h |
| 171 | 1.3.3.1.1 | Determine scope of Track 1 working group | manual | 30d | 2020-08-03 A | 2020-09-11 A |  | 100% |  |  |  |  | Contracted Parties; GDS Staff | 480h | 480h |
| 172 | 1.3.3.1.2 | Engage Operational Track 1 expert group |  | 150d | 2020-09-14 A | 2021-04-08 | 171 | 12% | 132d | 1367d |  |  | Contracted Parties; GDS Staff | 2400h | 288h |
| 173 | 1.3.3.2 | **IDN Policy Track 2 EPDP Working Group** |  | 690d | 2020-10-21 | 2023-06-08 |  |  |  | 0d |  |  |  | 12560h |  |
| 174 | 1.3.3.2.1 | Drafting Team to draft charter | manual | 90d | 2020-10-21 | 2021-02-23 |  |  |  |  |  |  | Council; Policy Staff | 1440h |  |
| 175 | 1.3.3.2.2 | Engage Track 2 EPDP working group |  | 250d | 2021-02-24 | 2022-02-04 | 171, 174 |  |  | 800d | 0d |  | GDS Staff; Policy Staff; Working Group | 6000h |  |
| 176 | 1.3.3.2.3 | Council to deliberate and adopt working group consensus recommendations |  | 40d | 2022-02-07 | 2022-04-01 | 175 |  |  | 800d | 0d |  | Council; Policy Staff | 640h |  |
| 177 | 1.3.3.2.4 | Board to deliberate and adopt consensus recommendations |  | 60d | 2022-04-04 | 2022-06-24 | 176 |  |  | 800d | 0d |  | Board | 480h |  |
| 178 | 1.3.3.2.5 | Engage IRT |  | 250d | 2022-06-27 | 2023-06-08 | 177 |  |  | 800d |  |  | GDS Staff; IRT | 4000h |  |
| 179 | 1.3.3.3 | **IDN Track 3 Council Coordination** |  | 375d | 2020-07-01 A | 2021-12-03 |  | 25% | 281.25d | 1195d |  |  |  | 6000h | 1500h |
| 180 | 1.3.3.3.1 | GNSO Council to coordinate with the CCNSO regarding IDN policy developments |  | 375d | 2020-07-01 A | 2021-12-03 |  | 25% | 281.25d | 1195d |  |  | Council; Policy Staff | 6000h | 1500h |
| 181 | 1.4 | **Expiration - Program Track** |  | 651d | 2020-10-01 A | 2023-03-28 |  | 23% | 502.2d | 853d |  |  |  | 2800h | 640h |
| 182 | 1.4.1 | **Expired Domain Deletion Policy (EDDP) / Expired Registration Recovery Policy (ERRP) Review** |  | 651d | 2020-10-01 A | 2023-03-28 |  | 23% | 502.2d | 853d |  |  |  | 2800h | 640h |
| 183 | 1.4.1.1 | Council to extend PSR for 18 months or when bandwidth becomes available | manual | 40d | 2020-10-01 A | 2020-11-25 A |  | 100% |  |  |  |  | Council; Policy Staff | 640h | 640h |
| 184 | 1.4.1.2 | Develop Policy Status Report (incl. Rec27 Wave1 EDDP Item 2 + ERRP Item3) |  | 90d | 2022-09-21 | 2023-01-24 | 183 |  |  | 853d | 0d | start no earlier than 2022-09-21 | GDS Staff; Policy Staff | 1440h |  |
| 185 | 1.4.1.3 | Council to deliberate findings |  | 45d | 2023-01-25 | 2023-03-28 | 184 |  |  | 853d |  |  | Council; Policy Staff | 720h |  |

Notes:
- 182: Expired Registration Recovery Policy Policy Review (ERRP_PR) / The ERRP Consensus Policy became effective 31 Aug 2013 as a result of adopted recommendations produced from the GNSOs Post Expiration Domain Name Recovery (PEDNR) PDP WG. That WG deliberated on issues related to the expiration of domain names and to what extent a Registrant should be able to recover domain names after they expire. One recommendation from the WG requested monitoring and follow-up: / Recommendation #18: The Working Group recommends that ICANN Compliance be requested to provide updates to the GNSO Council on a regular basis in relation to the implementation and effectiveness of the proposed recommendations, either in the form of a report that details amongst others the number of complaints received in relation to renewal and/or post expiration related matters or in the form of audits that assess if the policy has been implemented as intended.

| ID | WBS | Task | Type | Duration | Start | Finish | Predecessors | Complete | Remaining | Total slack | Free slack | Resources | Work | Actual work |
| --- | --- | --- | --- | --- | --- | --- | --- | --- | --- | --- | --- | --- | --- | --- |
| 186 | 1.5 | **Transfers - Program Track** |  | 1125d | 2020-07-01 A | 2024-10-16 |  | 12% | 988.12d | 445d |  |  | 18328h | 1096h |
| 187 | 1.5.1 | **Transfer Policy Review** |  | 1125d | 2020-07-01 A | 2024-10-16 |  | 12% | 988.12d | 445d |  |  | 18328h | 1096h |
| 188 | 1.5.1.1 | **Transfer Issue Report** |  | 170d | 2020-07-01 A | 2021-02-23 |  | 80% | 33.8d | 445d |  |  | 1368h | 1096h |
| 189 | 1.5.1.1.1 | Develop Issues Report |  | 170d | 2020-07-01 A | 2021-02-23 |  | 80% | 34d | 445d | 0d | Policy Staff | 1360h | 1088h |
| 190 | 1.5.1.1.2 | Staff to include as part of Transfer Review Issue Report (IRTP Items 4&5, TDRP Items 2-4) |  | 1d | 2021-01-13 A | 2021-01-13 A | 189 | 100% |  |  |  | Policy Staff | 8h | 8h |
| 191 | 1.5.1.2 | Council to approve PDP launch |  | 10d | 2021-02-24 | 2021-03-09 | 189 |  |  | 445d | 0d | Council; Policy Staff | 160h |  |
| 192 | 1.5.1.3 | Council to approve scope and charter |  | 35d | 2021-03-10 | 2021-04-26 | 191 |  |  | 445d | 0d | Council; Policy Staff | 560h |  |
| 193 | 1.5.1.4 | Engage Transfer Policy Review PDP |  | 540d | 2021-04-27 | 2023-05-18 | 192 |  |  | 445d | 0d | Working Group; Policy Staff | 8640h |  |
| 194 | 1.5.1.5 | Council to deliberate and adopt working group consensus recommendations |  | 40d | 2023-05-19 | 2023-07-12 | 193 |  |  | 445d | 0d | Council; Policy Staff | 640h |  |
| 195 | 1.5.1.6 | Board to deliberate and adopt consensus recommendations |  | 60d | 2023-07-13 | 2023-10-04 | 194 |  |  | 445d | 0d | Board | 480h |  |
| 196 | 1.5.1.7 | Engage IRT |  | 270d | 2023-10-05 | 2024-10-16 | 195 |  |  | 445d |  | IRT; GDS Staff; Policy Staff | 6480h |  |
| 197 | 1.6 | **IGO - Program Track** |  | 773d | 2020-07-01 A | 2023-06-13 |  |  | 773d | 797d |  |  | 25360h |  |
| 198 | 1.6.1 | **PDP: RPM - IGO Curative Rights Work Track** |  | 773d | 2020-07-01 A | 2023-06-13 |  |  | 773d | 797d |  |  | 11920h |  |
| 199 | 1.6.1.1 | Council to approve PDP launch | milestone | 0d | 2020-07-01 A | 2020-07-01 A |  | 100% |  |  |  | Council; Policy Staff |  |  |
| 200 | 1.6.1.2 | Council to approve scope and charter | milestone | 0d | 2020-07-01 A | 2020-07-01 A | 199 | 100% |  |  |  | Council; Policy Staff |  |  |
| 201 | 1.6.1.3 | Engage IGO-CRPM Work Track Policy Review PDP | manual | 270d | 2021-01-04 | 2022-01-12 | 200 |  |  |  |  | Working Group; Policy Staff | 4320h |  |
| 202 | 1.6.1.4 | Council to deliberate and adopt working group consensus recommendations |  | 40d | 2022-01-13 | 2022-03-09 | 201 |  |  | 797d | 0d | Council; Policy Staff | 640h |  |
| 203 | 1.6.1.5 | Board to deliberate and adopt consensus recommendations |  | 60d | 2022-03-10 | 2022-06-01 | 202 |  |  | 797d | 0d | Board | 480h |  |
| 204 | 1.6.1.6 | Engage IRT |  | 270d | 2022-06-02 | 2023-06-13 | 203 |  |  | 797d |  | GDS Staff; IRT; Policy Staff | 6480h |  |
| 205 | 1.6.2 | **PDP: Curative Rights Protections for IGO/INGOs** |  | 330d | 2022-03-10 | 2023-06-13 |  |  |  | 797d |  |  | 6960h |  |
| 206 | 1.6.2.1 | Board to deliberate and adopt consensus recommendations |  | 60d | 2022-03-10 | 2022-06-01 | 202 |  |  | 797d | 0d | Board | 480h |  |
| 207 | 1.6.2.2 | Engage IRT |  | 270d | 2022-06-02 | 2023-06-13 | 206 |  |  | 797d |  | GDS Staff; IRT; Policy Staff | 6480h |  |
| 208 | 1.6.3 | **PDP: Protection of International Organization Names in All gTLDs** |  | 270d | 2022-06-02 | 2023-06-13 |  |  |  | 797d |  |  | 6480h |  |
| 209 | 1.6.3.1 | Engage IRT |  | 270d | 2022-06-02 | 2023-06-13 | 206 |  |  | 797d |  | GDS Staff; IRT; Policy Staff | 6480h |  |

| ID | WBS | Task | Type | Duration | Start | Finish | Predecessors | Complete | Remaining | Total slack | Free slack | Resources | Work | Actual work |
| --- | --- | --- | --- | --- | --- | --- | --- | --- | --- | --- | --- | --- | --- | --- |
| 210 | 1.7 | **Accountability - Program Track** |  | 380d | 2020-07-01 A | 2021-12-10 |  | 15% | 321.27d | 1190d |  |  | 18560h | 2192h |
| 211 | 1.7.1 | **Independent Review Process - Implementation Oversight Team** |  | 100d | 2020-07-01 A | 2020-11-17 A |  | 100% |  |  |  |  | 800h | 800h |
| 212 | 1.7.1.1 | Engage IoT Oversight Team |  | 100d | 2020-07-01 A | 2020-11-17 A |  | 100% |  |  |  | Working Group | 800h | 800h |
| 213 | 1.7.2 | **Cross Community Working Group on Enhancing ICANN Accountability - WS2** |  | 350d | 2020-07-01 A | 2021-10-29 |  | 9% | 320d | 1220d |  |  | 5600h | 480h |
| 214 | 1.7.2.1 | Council small team to revew WS2 | manual | 150d | 2020-07-01 A | 2021-01-26 |  | 20% | 120d |  |  | Council; Policy Staff | 2400h | 480h |
| 215 | 1.7.2.2 | Council to determine what is required of the GNSO |  | 200d | 2021-01-27 | 2021-10-29 | 214 |  |  | 1220d |  | Council; Policy Staff | 3200h |  |
| 216 | 1.7.3 | **Multistakeholder Model Evolution** |  | 380d | 2020-07-01 A | 2021-12-10 |  | 10% | 342d | 1190d |  |  | 6080h | 608h |
| 217 | 1.7.3.1 | Council to determine what is required of the GNSO |  | 380d | 2020-07-01 A | 2021-12-10 |  | 10% | 342d | 1190d |  | Council; Policy Staff | 6080h | 608h |
| 218 | 1.7.4 | **Geo Regions Review** |  | 380d | 2020-07-01 A | 2021-12-10 |  | 5% | 361d | 1190d |  |  | 6080h | 304h |
| 219 | 1.7.4.1 | Council to determine what is required of the GNSO |  | 380d | 2020-07-01 A | 2021-12-10 |  | 5% | 361d | 1190d |  | Council; Policy Staff | 6080h | 304h |
| 220 | 1.8 | **Reviews - Program Track** |  | 1568d | 2020-07-01 A | 2026-06-26 |  | 9% | 1429.04d | 2d |  |  | 28872h | 2276h |
| 221 | 1.8.1 | **IANA Naming Function Review** |  | 190d | 2020-07-01 A | 2021-03-22 |  | 39% | 115d | 1380d |  |  | 1520h | 600h |
| 222 | 1.8.1.1 | Council SSC to select GNSO representatives on Review Team | milestone | 0d | 2020-07-01 A | 2020-07-01 A |  | 100% |  |  |  | Policy Staff; SSC |  |  |
| 223 | 1.8.1.2 | GNSO participation on IFRT2 |  | 190d | 2020-07-01 A | 2021-03-22 | 222 | 39% | 115d | 1380d |  | Working Group | 1520h | 600h |
| 224 | 1.8.2 | **GNSO Review RT3** |  | 670d | 2021-06-01 | 2023-12-20 |  |  |  | 0d |  |  | 10240h |  |
| 225 | 1.8.2.1 | Council SSC to select GNSO representatives on Review Team | manual | 30d | 2021-06-01 | 2021-07-12 |  |  |  |  |  | Policy Staff; SSC | 480h |  |
| 226 | 1.8.2.2 | GNSO participation on GNSO3-RT |  | 270d | 2021-07-13 | 2022-07-22 | 225 |  |  | 660d | 0d | Working Group; Policy Staff | 4320h |  |
| 227 | 1.8.2.3 | Council to deliberate and adopt review team consensus recommendations |  | 40d | 2022-07-25 | 2022-09-16 | 226 |  |  | 660d | 0d | Council; Policy Staff | 640h |  |
| 228 | 1.8.2.4 | Board to deliberate and adopt consensus recommendations |  | 60d | 2022-09-19 | 2022-12-09 | 227 |  |  | 660d | 0d | Board | 480h |  |
| 229 | 1.8.2.5 | Implement GNSO3 Review recommendations |  | 270d | 2022-12-12 | 2023-12-20 | 228 |  |  | 660d |  | Council; Policy Staff | 4320h |  |
| 230 | 1.8.3 | **Customer Standing Committee Effectiveness Review** |  | 180d | 2022-03-01 | 2022-11-07 |  |  |  | 0d |  |  | 1680h |  |
| 231 | 1.8.3.1 | Council SSC to select GNSO representatives on Review Team | manual | 30d | 2022-03-01 | 2022-04-11 |  |  |  |  |  | Policy Staff; SSC | 480h |  |
| 232 | 1.8.3.2 | GNSO participation on CSC2-ER |  | 150d | 2022-04-12 | 2022-11-07 | 231 |  |  | 954d |  | Working Group | 1200h |  |
| 233 | 1.8.4 | **Registration Directory Service Review RT3** |  | 300d | 2024-09-02 | 2025-10-23 |  |  |  | 0d |  |  | 2640h |  |
| 234 | 1.8.4.1 | Council SSC to select GNSO representatives on Review Team | manual | 30d | 2024-09-02 | 2024-10-11 |  |  |  |  |  | Policy Staff; SSC | 480h |  |
| 235 | 1.8.4.2 | GNSO participation on RDS3-RT |  | 270d | 2024-10-14 | 2025-10-23 | 234 |  |  | 178d |  | Working Group | 2160h |  |

| ID | WBS | Task | Type | Duration | Start | Finish | Predecessors | Complete | Remaining | Total slack | Free slack | Constraint | Resources | Work | Actual work |
| --- | --- | --- | --- | --- | --- | --- | --- | --- | --- | --- | --- | --- | --- | --- | --- |
| 236 | 1.8.5 | **Competition, Consumer Trust and Consumer Choice RT2** |  | 300d | 2023-01-03 | 2024-02-22 |  |  |  | 0d |  |  |  | 2640h |  |
| 237 | 1.8.5.1 | Council SSC to select GNSO representatives on Review Team | manual | 30d | 2023-01-03 | 2023-02-13 |  |  |  |  |  |  | SSC; Policy Staff | 480h |  |
| 238 | 1.8.5.2 | GNSO participation on CCT-RT2 |  | 270d | 2023-02-14 | 2024-02-22 | 237 |  |  | 614d |  |  | Working Group | 2160h |  |
| 239 | 1.8.6 | **Accountability and Transparency Review 3** |  | 260d | 2020-07-01 A | 2021-06-28 |  | 22% | 203.76d | 1310d |  |  |  | 4512h | 976h |
| 240 | 1.8.6.1 | Council to form a small team to draft a public comment response to the ATRT3 |  | 22d | 2020-07-01 A | 2020-07-30 A |  | 100% |  |  |  |  | Policy Staff; Council | 352h | 352h |
| 241 | 1.8.6.2 | Council to monitor for ATRT3 implementation assignments should the Board adopt ATRT3 recommendations |  | 260d | 2020-07-01 A | 2021-06-28 |  | 15% | 221d | 1310d |  | start no earlier than 2020-07-01 | Council; Policy Staff | 4160h | 624h |
| 242 | 1.8.7 | **Accountability and Transparency Review 4** |  | 280d | 2025-06-02 | 2026-06-26 |  |  |  | 0d |  |  |  | 2480h |  |
| 243 | 1.8.7.1 | Council SSC to select GNSO representatives on Review Team | manual | 30d | 2025-06-02 | 2025-07-11 |  |  |  |  |  |  | Policy Staff; SSC | 480h |  |
| 244 | 1.8.7.2 | GNSO participation on ATRT4 |  | 250d | 2025-07-14 | 2026-06-26 | 243 |  |  | 2d |  |  | Working Group | 2000h |  |
| 245 | 1.8.8 | **Security, Stability and Resiliency of the DNS #2** |  | 170d | 2020-07-01 A | 2021-02-23 |  | 51% | 82.5d | 1400d |  |  |  | 1720h | 700h |
| 246 | 1.8.8.1 | GNSO participation on SSR#2 |  | 125d | 2020-07-01 A | 2020-12-22 |  | 70% | 37.5d | 1400d | 0d |  | Working Group | 1000h | 700h |
| 247 | 1.8.8.2 | Council to consider SSR#2 Results |  | 45d | 2020-12-23 | 2021-02-23 | 246 |  |  | 1400d |  |  | Council; Policy Staff | 720h |  |
| 248 | 1.8.9 | **Security, Stability and Resiliency of the DNS #3** |  | 150d | 2025-12-01 | 2026-06-26 |  |  |  | 0d |  |  |  | 1440h |  |
| 249 | 1.8.9.1 | Council SSC to select GNSO representatives on Review Team | manual | 30d | 2025-12-01 | 2026-01-09 |  |  |  |  |  |  | Policy Staff; SSC | 480h |  |
| 250 | 1.8.9.2 | GNSO participation on SSR3 |  | 120d | 2026-01-12 | 2026-06-26 | 249 |  |  | 2d |  |  | Working Group | 960h |  |
| 251 | 1.9 | **Operations - Program Track** |  | 1570d | 2020-07-01 A | 2026-06-30 |  | 9% | 1432.38d | 0d |  |  |  | 100608h | 8817.6h |
| 252 | 1.9.1 | **Policy & Implementation - Recommendations Review** |  | 477d | 2020-10-05 | 2022-07-29 |  |  |  | 0d |  |  |  | 2120h |  |
| 253 | 1.9.1.1 | Council to decide to extend review beyond 5 years from Final Report | manual | 55d | 2020-10-05 | 2020-12-18 |  |  |  |  |  |  | Council | 440h |  |
| 254 | 1.9.1.2 | Survey community (EPDP) on P&I features | manual | 60d | 2022-01-03 | 2022-03-25 | 253 |  |  |  |  |  | Policy Staff | 480h |  |
| 255 | 1.9.1.3 | Review IRT principles and CPIF | manual | 90d | 2022-01-03 | 2022-05-06 | 253 |  |  |  |  |  | GDS Staff | 720h |  |
| 256 | 1.9.1.4 | Determine if additional review is required |  | 60d | 2022-05-09 | 2022-07-29 | 254, 255 |  |  | 1025d |  |  | Council | 480h |  |
| 257 | 1.9.2 | **Participant of Empowered Community** |  | 1406d | 2020-07-01 A | 2025-11-12 |  | 7% | 1310d | 164d |  |  |  | 23096h | 1656h |
| 258 | 1.9.2.1 | Perform role 2020 | manual | 81d | 2020-07-01 A | 2020-10-21 A |  | 100% |  |  |  |  | EC Rep; EC Admin | 1296h | 1296h |
| 259 | 1.9.2.2 | Elect new participant |  | 15d | 2020-10-22 A | 2020-11-11 A | 258 | 100% |  |  |  |  | Council; Policy Staff; EC Admin | 360h | 360h |
| 260 | 1.9.2.3 | Perform role 2021 |  | 250d | 2020-11-12 | 2021-10-25 | 259 |  |  | 164d | 0d |  | EC Admin; EC Rep | 4000h |  |
| 261 | 1.9.2.4 | Elect new participant |  | 15d | 2021-10-26 | 2021-11-15 | 260 |  |  | 164d | 0d |  | Council; Policy Staff; EC Admin | 360h |  |
| 262 | 1.9.2.5 | Perform role 2022 |  | 250d | 2021-11-16 | 2022-10-31 | 261 |  |  | 164d | 0d |  | EC Admin; EC Rep | 4000h |  |
| 263 | 1.9.2.6 | Elect new participant |  | 15d | 2022-11-01 | 2022-11-21 | 262 |  |  | 164d | 0d |  | Council; Policy Staff; EC Admin | 360h |  |
| 264 | 1.9.2.7 | Perform role 2023 |  | 250d | 2022-11-22 | 2023-11-02 | 263 |  |  | 164d | 0d |  | EC Admin; EC Rep | 4000h |  |
| 265 | 1.9.2.8 | Elect new participant |  | 15d | 2023-11-03 | 2023-11-23 | 264 |  |  | 164d | 0d |  | Council; Policy Staff; EC Admin | 360h |  |
| 266 | 1.9.2.9 | Perform role 2024 |  | 250d | 2023-11-24 | 2024-11-07 | 265 |  |  | 164d | 0d |  | EC Admin; EC Rep | 4000h |  |
| 267 | 1.9.2.10 | Elect new participant |  | 15d | 2024-11-08 | 2024-11-28 | 266 |  |  | 164d | 0d |  | Council; Policy Staff; EC Admin | 360h |  |
| 268 | 1.9.2.11 | Perform role 2025 |  | 250d | 2024-11-29 | 2025-11-12 | 267 |  |  | 164d |  |  | EC Admin; EC Rep | 4000h |  |

Notes:
- 252: Policy & Implementation Recommendations Review (PolImp_RR) / As noted in Point H of the CPIF, which directs ICANN staff [to] continually review the implementation framework and related materials to encapsulate additional best-practices or to adjust the steps as a result of lessons learned with previous Consensus Policy projects, a cross-functional group of representatives from ICANNs GDD and GNSO Policy Development Support teams have reviewed the Framework, and proposed a number of amendments to it for the consideration of the GNSO Council. Following review by the GNSO Council, this updated version has now been posted.~ / The GNSO Council resolved in June 2015 that a review of these recommendations is carried out at the latest five years following their implementation to assess whether the recommendations have achieved what they set out to do and/or whether any further enhancements or changes are needed.

| ID | WBS | Task | Type | Duration | Start | Finish | Complete | Remaining | Total slack | Constraint | Resources | Work | Actual work |
| --- | --- | --- | --- | --- | --- | --- | --- | --- | --- | --- | --- | --- | --- |
| 269 | 1.9.3 | **GNSO Council** |  | 1570d | 2020-07-01 A | 2026-06-30 | 10% | 1413.6d | 0d |  |  | 75392h | 7161.6h |
| 270 | 1.9.3.1 | **GNSO Council - Monthly Meetings** |  | 1545d | 2020-07-23 A | 2026-06-17 | 8% | 1416.25d | 0d |  |  | 1152h | 96h |
| 271 | 1.9.3.1.1 | GNSO Council Meeting | manual | 1d | 2020-07-23 A | 2020-07-23 A | 100% |  |  | start no earlier than 2020-07-23 | Council; Policy Staff | 16h | 16h |
| 272 | 1.9.3.1.2 | GNSO Council Meeting | manual | 1d | 2020-08-20 A | 2020-08-20 A | 100% |  |  | start no earlier than 2020-08-20 | Council; Policy Staff | 16h | 16h |
| 273 | 1.9.3.1.3 | GNSO Council Meeting | manual | 1d | 2020-09-24 A | 2020-09-24 A | 100% |  |  | start no earlier than 2020-09-24 | Council; Policy Staff | 16h | 16h |
| 274 | 1.9.3.1.4 | GNSO Council Meeting | manual | 1d | 2020-10-21 A | 2020-10-21 A | 100% |  |  | start no earlier than 2020-10-21 | Council; Policy Staff | 16h | 16h |
| 275 | 1.9.3.1.5 | GNSO Council Meeting | manual | 1d | 2020-11-19 A | 2020-11-19 A | 100% |  |  | start no earlier than 2020-11-19 | Council; Policy Staff | 16h | 16h |
| 276 | 1.9.3.1.6 | GNSO Council Meeting | manual | 1d | 2020-12-17 A | 2020-12-17 A | 100% |  |  | start no earlier than 2020-12-17 | Council; Policy Staff | 16h | 16h |
| 277 | 1.9.3.1.7 | GNSO Council Meeting | manual | 1d | 2021-01-21 | 2021-01-21 |  |  |  | start no earlier than 2021-01-21 | Council; Policy Staff | 16h |  |
| 278 | 1.9.3.1.8 | GNSO Council Meeting | manual | 1d | 2021-02-18 | 2021-02-18 |  |  |  | start no earlier than 2021-02-18 | Council; Policy Staff | 16h |  |
| 279 | 1.9.3.1.9 | GNSO Council Meeting | manual | 1d | 2021-03-24 | 2021-03-24 |  |  |  | start no earlier than 2021-03-24 | Council; Policy Staff | 16h |  |
| 280 | 1.9.3.1.10 | GNSO Council Meeting | manual | 1d | 2021-04-22 | 2021-04-22 |  |  |  | start no earlier than 2021-04-22 | Council; Policy Staff | 16h |  |
| 281 | 1.9.3.1.11 | GNSO Council Meeting | manual | 1d | 2021-05-20 | 2021-05-20 |  |  |  | start no earlier than 2021-05-20 | Council; Policy Staff | 16h |  |
| 282 | 1.9.3.1.12 | GNSO Council Meeting | manual | 1d | 2021-06-16 | 2021-06-16 |  |  |  | start no earlier than 2021-06-16 | Council; Policy Staff | 16h |  |
| 283 | 1.9.3.1.13 | GNSO Council Meeting | manual | 1d | 2021-07-22 | 2021-07-22 |  |  |  | start no earlier than 2021-07-22 | Council; Policy Staff | 16h |  |
| 284 | 1.9.3.1.14 | GNSO Council Meeting | manual | 1d | 2021-08-19 | 2021-08-19 |  |  |  | start no earlier than 2021-08-19 | Council; Policy Staff | 16h |  |
| 285 | 1.9.3.1.15 | GNSO Council Meeting | manual | 1d | 2021-09-23 | 2021-09-23 |  |  |  | start no earlier than 2021-09-23 | Council; Policy Staff | 16h |  |
| 286 | 1.9.3.1.16 | GNSO Council Meeting | manual | 1d | 2021-10-27 | 2021-10-27 |  |  |  | start no earlier than 2021-10-27 | Council; Policy Staff | 16h |  |
| 287 | 1.9.3.1.17 | GNSO Council Meeting | manual | 1d | 2021-11-18 | 2021-11-18 |  |  |  | start no earlier than 2021-11-18 | Council; Policy Staff | 16h |  |
| 288 | 1.9.3.1.18 | GNSO Council Meeting | manual | 1d | 2021-12-16 | 2021-12-16 |  |  |  | start no earlier than 2021-12-16 | Council; Policy Staff | 16h |  |
| 289 | 1.9.3.1.19 | GNSO Council Meeting | manual | 1d | 2022-01-20 | 2022-01-20 |  |  |  | start no earlier than 2022-01-20 | Council; Policy Staff | 16h |  |
| 290 | 1.9.3.1.20 | GNSO Council Meeting | manual | 1d | 2022-02-17 | 2022-02-17 |  |  |  | start no earlier than 2022-02-17 | Council; Policy Staff | 16h |  |
| 291 | 1.9.3.1.21 | GNSO Council Meeting | manual | 1d | 2022-03-24 | 2022-03-24 |  |  |  | start no earlier than 2022-03-24 | Council; Policy Staff | 16h |  |
| 292 | 1.9.3.1.22 | GNSO Council Meeting | manual | 1d | 2022-04-21 | 2022-04-21 |  |  |  | start no earlier than 2022-04-21 | Council; Policy Staff | 16h |  |
| 293 | 1.9.3.1.23 | GNSO Council Meeting | manual | 1d | 2022-05-19 | 2022-05-19 |  |  |  | start no earlier than 2022-05-19 | Council; Policy Staff | 16h |  |
| 294 | 1.9.3.1.24 | GNSO Council Meeting | manual | 1d | 2022-06-22 | 2022-06-22 |  |  |  | start no earlier than 2022-06-22 | Council; Policy Staff | 16h |  |
| 295 | 1.9.3.1.25 | GNSO Council Meeting | manual | 1d | 2022-07-21 | 2022-07-21 |  |  |  | start no earlier than 2022-07-21 | Council; Policy Staff | 16h |  |
| 296 | 1.9.3.1.26 | GNSO Council Meeting | manual | 1d | 2022-08-18 | 2022-08-18 |  |  |  | start no earlier than 2022-08-18 | Council; Policy Staff | 16h |  |
| 297 | 1.9.3.1.27 | GNSO Council Meeting | manual | 1d | 2022-09-22 | 2022-09-22 |  |  |  | start no earlier than 2022-09-22 | Council; Policy Staff | 16h |  |
| 298 | 1.9.3.1.28 | GNSO Council Meeting | manual | 1d | 2022-10-19 | 2022-10-19 |  |  |  | start no earlier than 2022-10-19 | Council; Policy Staff | 16h |  |
| 299 | 1.9.3.1.29 | GNSO Council Meeting | manual | 1d | 2022-11-17 | 2022-11-17 |  |  |  | start no earlier than 2022-11-17 | Council; Policy Staff | 16h |  |
| 300 | 1.9.3.1.30 | GNSO Council Meeting | manual | 1d | 2022-12-15 | 2022-12-15 |  |  |  | start no earlier than 2022-12-15 | Council; Policy Staff | 16h |  |
| 301 | 1.9.3.1.31 | GNSO Council Meeting | manual | 1d | 2023-01-19 | 2023-01-19 |  |  |  | start no earlier than 2023-01-19 | Council; Policy Staff | 16h |  |
| 302 | 1.9.3.1.32 | GNSO Council Meeting | manual | 1d | 2023-02-16 | 2023-02-16 |  |  |  | start no earlier than 2023-02-16 | Council; Policy Staff | 16h |  |
| 303 | 1.9.3.1.33 | GNSO Council Meeting | manual | 1d | 2023-03-22 | 2023-03-22 |  |  |  | start no earlier than 2023-03-22 | Council; Policy Staff | 16h |  |
| 304 | 1.9.3.1.34 | GNSO Council Meeting | manual | 1d | 2023-04-20 | 2023-04-20 |  |  |  | start no earlier than 2023-04-20 | Council; Policy Staff | 16h |  |
| 305 | 1.9.3.1.35 | GNSO Council Meeting | manual | 1d | 2023-05-18 | 2023-05-18 |  |  |  | start no earlier than 2023-05-18 | Council; Policy Staff | 16h |  |
| 306 | 1.9.3.1.36 | GNSO Council Meeting | manual | 1d | 2023-06-21 | 2023-06-21 |  |  |  | start no earlier than 2023-06-21 | Council; Policy Staff | 16h |  |
| 307 | 1.9.3.1.37 | GNSO Council Meeting | manual | 1d | 2023-07-20 | 2023-07-20 |  |  |  | start no earlier than 2023-07-20 | Council; Policy Staff | 16h |  |
| 308 | 1.9.3.1.38 | GNSO Council Meeting | manual | 1d | 2023-08-17 | 2023-08-17 |  |  |  | start no earlier than 2023-08-17 | Council; Policy Staff | 16h |  |
| 309 | 1.9.3.1.39 | GNSO Council Meeting | manual | 1d | 2023-09-21 | 2023-09-21 |  |  |  | start no earlier than 2023-09-21 | Council; Policy Staff | 16h |  |
| 310 | 1.9.3.1.40 | GNSO Council Meeting | manual | 1d | 2023-10-18 | 2023-10-18 |  |  |  | start no earlier than 2023-10-18 | Council; Policy Staff | 16h |  |
| 311 | 1.9.3.1.41 | GNSO Council Meeting | manual | 1d | 2023-11-16 | 2023-11-16 |  |  |  | start no earlier than 2023-11-16 | Council; Policy Staff | 16h |  |
| 312 | 1.9.3.1.42 | GNSO Council Meeting | manual | 1d | 2023-12-14 | 2023-12-14 |  |  |  | start no earlier than 2023-12-14 | Council; Policy Staff | 16h |  |
| 313 | 1.9.3.1.43 | GNSO Council Meeting | manual | 1d | 2024-01-18 | 2024-01-18 |  |  |  | start no earlier than 2024-01-18 | Council; Policy Staff | 16h |  |
| 314 | 1.9.3.1.44 | GNSO Council Meeting | manual | 1d | 2024-02-15 | 2024-02-15 |  |  |  | start no earlier than 2024-02-15 | Council; Policy Staff | 16h |  |
| 315 | 1.9.3.1.45 | GNSO Council Meeting | manual | 1d | 2024-03-20 | 2024-03-20 |  |  |  | start no earlier than 2024-03-20 | Council; Policy Staff | 16h |  |
| 316 | 1.9.3.1.46 | GNSO Council Meeting | manual | 1d | 2024-04-18 | 2024-04-18 |  |  |  | start no earlier than 2024-04-18 | Council; Policy Staff | 16h |  |
| 317 | 1.9.3.1.47 | GNSO Council Meeting | manual | 1d | 2024-05-16 | 2024-05-16 |  |  |  | start no earlier than 2024-05-16 | Council; Policy Staff | 16h |  |
| 318 | 1.9.3.1.48 | GNSO Council Meeting | manual | 1d | 2024-06-19 | 2024-06-19 |  |  |  | start no earlier than 2024-06-19 | Council; Policy Staff | 16h |  |
| 319 | 1.9.3.1.49 | GNSO Council Meeting | manual | 1d | 2024-07-18 | 2024-07-18 |  |  |  | start no earlier than 2024-07-18 | Council; Policy Staff | 16h |  |
| 320 | 1.9.3.1.50 | GNSO Council Meeting | manual | 1d | 2024-08-15 | 2024-08-15 |  |  |  | start no earlier than 2024-08-15 | Council; Policy Staff | 16h |  |
| 321 | 1.9.3.1.51 | GNSO Council Meeting | manual | 1d | 2024-09-19 | 2024-09-19 |  |  |  | start no earlier than 2024-09-19 | Council; Policy Staff | 16h |  |
| 322 | 1.9.3.1.52 | GNSO Council Meeting | manual | 1d | 2024-10-23 | 2024-10-23 |  |  |  | start no earlier than 2024-10-23 | Council; Policy Staff | 16h |  |
| 323 | 1.9.3.1.53 | GNSO Council Meeting | manual | 1d | 2024-11-14 | 2024-11-14 |  |  |  | start no earlier than 2024-11-14 | Council; Policy Staff | 16h |  |
| 324 | 1.9.3.1.54 | GNSO Council Meeting | manual | 1d | 2024-12-12 | 2024-12-12 |  |  |  | start no earlier than 2024-12-12 | Council; Policy Staff | 16h |  |
| 325 | 1.9.3.1.55 | GNSO Council Meeting | manual | 1d | 2025-01-16 | 2025-01-16 |  |  |  | start no earlier than 2025-01-16 | Council; Policy Staff | 16h |  |
| 326 | 1.9.3.1.56 | GNSO Council Meeting | manual | 1d | 2025-02-13 | 2025-02-13 |  |  |  | start no earlier than 2025-02-13 | Council; Policy Staff | 16h |  |
| 327 | 1.9.3.1.57 | GNSO Council Meeting | manual | 1d | 2025-03-19 | 2025-03-19 |  |  |  | start no earlier than 2025-03-19 | Council; Policy Staff | 16h |  |
| 328 | 1.9.3.1.58 | GNSO Council Meeting | manual | 1d | 2025-04-17 | 2025-04-17 |  |  |  | start no earlier than 2025-04-17 | Council; Policy Staff | 16h |  |
| 329 | 1.9.3.1.59 | GNSO Council Meeting | manual | 1d | 2025-05-15 | 2025-05-15 |  |  |  | start no earlier than 2025-05-15 | Council; Policy Staff | 16h |  |
| 330 | 1.9.3.1.60 | GNSO Council Meeting | manual | 1d | 2025-06-18 | 2025-06-18 |  |  |  | start no earlier than 2025-06-18 | Council; Policy Staff | 16h |  |
| 331 | 1.9.3.1.61 | GNSO Council Meeting | manual | 1d | 2025-07-17 | 2025-07-17 |  |  |  | start no earlier than 2025-07-17 | Council; Policy Staff | 16h |  |
| 332 | 1.9.3.1.62 | GNSO Council Meeting | manual | 1d | 2025-08-21 | 2025-08-21 |  |  |  | start no earlier than 2025-08-21 | Council; Policy Staff | 16h |  |
| 333 | 1.9.3.1.63 | GNSO Council Meeting | manual | 1d | 2025-09-18 | 2025-09-18 |  |  |  | start no earlier than 2025-09-18 | Council; Policy Staff | 16h |  |
| 334 | 1.9.3.1.64 | GNSO Council Meeting | manual | 1d | 2025-10-22 | 2025-10-22 |  |  |  | start no earlier than 2025-10-22 | Council; Policy Staff | 16h |  |
| 335 | 1.9.3.1.65 | GNSO Council Meeting | manual | 1d | 2025-11-13 | 2025-11-13 |  |  |  | start no earlier than 2025-11-13 | Council; Policy Staff | 16h |  |
| 336 | 1.9.3.1.66 | GNSO Council Meeting | manual | 1d | 2025-12-18 | 2025-12-18 |  |  |  | start no earlier than 2025-12-18 | Council; Policy Staff | 16h |  |
| 337 | 1.9.3.1.67 | GNSO Council Meeting | manual | 1d | 2026-01-15 | 2026-01-15 |  |  |  | start no earlier than 2026-01-15 | Council; Policy Staff | 16h |  |
| 338 | 1.9.3.1.68 | GNSO Council Meeting | manual | 1d | 2026-02-19 | 2026-02-19 |  |  |  | start no earlier than 2026-02-19 | Council; Policy Staff | 16h |  |

| ID | WBS | Task | Type | Duration | Start | Finish | Complete | Remaining | Total slack | Constraint | Resources | Work | Actual work |
| --- | --- | --- | --- | --- | --- | --- | --- | --- | --- | --- | --- | --- | --- |
| 339 | 1.9.3.1.69 | GNSO Council Meeting | manual | 1d | 2026-03-18 | 2026-03-18 |  |  |  | start no earlier than 2026-03-18 | Council; Policy Staff | 16h |  |
| 340 | 1.9.3.1.70 | GNSO Council Meeting | manual | 1d | 2026-04-16 | 2026-04-16 |  |  |  | start no earlier than 2026-04-16 | Council; Policy Staff | 16h |  |
| 341 | 1.9.3.1.71 | GNSO Council Meeting | manual | 1d | 2026-05-14 | 2026-05-14 |  |  |  | start no earlier than 2026-05-14 | Council; Policy Staff | 16h |  |
| 342 | 1.9.3.1.72 | GNSO Council Meeting | manual | 1d | 2026-06-17 | 2026-06-17 |  |  |  | start no earlier than 2026-06-17 | Council; Policy Staff | 16h |  |
| 343 | 1.9.3.2 | **GNSO Council - Leadership Meetings** |  | 1554d | 2020-07-13 A | 2026-06-18 | 8% | 1424.5d | 0d |  |  | 2304h | 192h |
| 344 | 1.9.3.2.1 | GNSO Council - Leadership Meetings | manual | 2d | 2020-07-13 A | 2020-07-14 A | 100% |  |  | start no earlier than 2020-07-13 | Council Leads; Policy Staff | 32h | 32h |
| 345 | 1.9.3.2.2 | GNSO Council - Leadership Meetings | manual | 2d | 2020-08-10 A | 2020-08-11 A | 100% |  |  | start no earlier than 2020-08-10 | Council Leads; Policy Staff | 32h | 32h |
| 346 | 1.9.3.2.3 | GNSO Council - Leadership Meetings | manual | 2d | 2020-09-14 A | 2020-09-15 A | 100% |  |  | start no earlier than 2020-09-14 | Council Leads; Policy Staff | 32h | 32h |
| 347 | 1.9.3.2.4 | GNSO Council - Leadership Meetings | manual | 2d | 2020-10-12 A | 2020-10-13 A | 100% |  |  | start no earlier than 2020-10-12 | Council Leads; Policy Staff | 32h | 32h |
| 348 | 1.9.3.2.5 | GNSO Council - Leadership Meetings | manual | 2d | 2020-11-09 A | 2020-11-10 A | 100% |  |  | start no earlier than 2020-11-09 | Council Leads; Policy Staff | 32h | 32h |
| 349 | 1.9.3.2.6 | GNSO Council - Leadership Meetings | manual | 2d | 2020-12-14 A | 2020-12-15 A | 100% |  |  | start no earlier than 2020-12-14 | Council Leads; Policy Staff | 32h | 32h |
| 350 | 1.9.3.2.7 | GNSO Council - Leadership Meetings | manual | 2d | 2021-01-11 | 2021-01-12 |  |  |  | start no earlier than 2021-01-11 | Council Leads; Policy Staff | 32h |  |
| 351 | 1.9.3.2.8 | GNSO Council - Leadership Meetings | manual | 2d | 2021-02-08 | 2021-02-09 |  |  |  | start no earlier than 2021-02-08 | Council Leads; Policy Staff | 32h |  |
| 352 | 1.9.3.2.9 | GNSO Council - Leadership Meetings | manual | 2d | 2021-03-08 | 2021-03-09 |  |  |  | start no earlier than 2021-03-08 | Council Leads; Policy Staff | 32h |  |
| 353 | 1.9.3.2.10 | GNSO Council - Leadership Meetings | manual | 2d | 2021-04-12 | 2021-04-13 |  |  |  | start no earlier than 2021-04-12 | Council Leads; Policy Staff | 32h |  |
| 354 | 1.9.3.2.11 | GNSO Council - Leadership Meetings | manual | 2d | 2021-05-10 | 2021-05-11 |  |  |  | start no earlier than 2021-05-10 | Council Leads; Policy Staff | 32h |  |
| 355 | 1.9.3.2.12 | GNSO Council - Leadership Meetings | manual | 2d | 2021-06-14 | 2021-06-15 |  |  |  | start no earlier than 2021-06-14 | Council Leads; Policy Staff | 32h |  |
| 356 | 1.9.3.2.13 | GNSO Council - Leadership Meetings | manual | 2d | 2021-07-12 | 2021-07-13 |  |  |  | start no earlier than 2021-07-12 | Council Leads; Policy Staff | 32h |  |
| 357 | 1.9.3.2.14 | GNSO Council - Leadership Meetings | manual | 2d | 2021-08-09 | 2021-08-10 |  |  |  | start no earlier than 2021-08-09 | Council Leads; Policy Staff | 32h |  |
| 358 | 1.9.3.2.15 | GNSO Council - Leadership Meetings | manual | 2d | 2021-09-13 | 2021-09-14 |  |  |  | start no earlier than 2021-09-13 | Council Leads; Policy Staff | 32h |  |
| 359 | 1.9.3.2.16 | GNSO Council - Leadership Meetings | manual | 2d | 2021-10-11 | 2021-10-12 |  |  |  | start no earlier than 2021-10-11 | Council Leads; Policy Staff | 32h |  |
| 360 | 1.9.3.2.17 | GNSO Council - Leadership Meetings | manual | 2d | 2021-11-08 | 2021-11-09 |  |  |  | start no earlier than 2021-11-08 | Council Leads; Policy Staff | 32h |  |
| 361 | 1.9.3.2.18 | GNSO Council - Leadership Meetings | manual | 2d | 2021-12-13 | 2021-12-14 |  |  |  | start no earlier than 2021-12-13 | Council Leads; Policy Staff | 32h |  |
| 362 | 1.9.3.2.19 | GNSO Council - Leadership Meetings | manual | 2d | 2022-01-20 | 2022-01-21 |  |  |  | start no earlier than 2022-01-20 | Policy Staff; Council Leads | 32h |  |
| 363 | 1.9.3.2.20 | GNSO Council - Leadership Meetings | manual | 2d | 2022-02-17 | 2022-02-18 |  |  |  | start no earlier than 2022-02-17 | Policy Staff; Council Leads | 32h |  |
| 364 | 1.9.3.2.21 | GNSO Council - Leadership Meetings | manual | 2d | 2022-03-24 | 2022-03-25 |  |  |  | start no earlier than 2022-03-24 | Policy Staff; Council Leads | 32h |  |
| 365 | 1.9.3.2.22 | GNSO Council - Leadership Meetings | manual | 2d | 2022-04-21 | 2022-04-22 |  |  |  | start no earlier than 2022-04-21 | Policy Staff; Council Leads | 32h |  |
| 366 | 1.9.3.2.23 | GNSO Council - Leadership Meetings | manual | 2d | 2022-05-19 | 2022-05-20 |  |  |  | start no earlier than 2022-05-19 | Policy Staff; Council Leads | 32h |  |
| 367 | 1.9.3.2.24 | GNSO Council - Leadership Meetings | manual | 2d | 2022-06-22 | 2022-06-23 |  |  |  | start no earlier than 2022-06-22 | Policy Staff; Council Leads | 32h |  |
| 368 | 1.9.3.2.25 | GNSO Council - Leadership Meetings | manual | 2d | 2022-07-21 | 2022-07-22 |  |  |  | start no earlier than 2022-07-21 | Policy Staff; Council Leads | 32h |  |
| 369 | 1.9.3.2.26 | GNSO Council - Leadership Meetings | manual | 2d | 2022-08-18 | 2022-08-19 |  |  |  | start no earlier than 2022-08-18 | Policy Staff; Council Leads | 32h |  |
| 370 | 1.9.3.2.27 | GNSO Council - Leadership Meetings | manual | 2d | 2022-09-22 | 2022-09-23 |  |  |  | start no earlier than 2022-09-22 | Policy Staff; Council Leads | 32h |  |
| 371 | 1.9.3.2.28 | GNSO Council - Leadership Meetings | manual | 2d | 2022-10-19 | 2022-10-20 |  |  |  | start no earlier than 2022-10-19 | Policy Staff; Council Leads | 32h |  |
| 372 | 1.9.3.2.29 | GNSO Council - Leadership Meetings | manual | 2d | 2022-11-17 | 2022-11-18 |  |  |  | start no earlier than 2022-11-17 | Policy Staff; Council Leads | 32h |  |
| 373 | 1.9.3.2.30 | GNSO Council - Leadership Meetings | manual | 2d | 2022-12-15 | 2022-12-16 |  |  |  | start no earlier than 2022-12-15 | Policy Staff; Council Leads | 32h |  |
| 374 | 1.9.3.2.31 | GNSO Council - Leadership Meetings | manual | 2d | 2023-01-19 | 2023-01-20 |  |  |  | start no earlier than 2023-01-19 | Policy Staff; Council Leads | 32h |  |
| 375 | 1.9.3.2.32 | GNSO Council - Leadership Meetings | manual | 2d | 2023-02-16 | 2023-02-17 |  |  |  | start no earlier than 2023-02-16 | Policy Staff; Council Leads | 32h |  |
| 376 | 1.9.3.2.33 | GNSO Council - Leadership Meetings | manual | 2d | 2023-03-22 | 2023-03-23 |  |  |  | start no earlier than 2023-03-22 | Policy Staff; Council Leads | 32h |  |
| 377 | 1.9.3.2.34 | GNSO Council - Leadership Meetings | manual | 2d | 2023-04-20 | 2023-04-21 |  |  |  | start no earlier than 2023-04-20 | Policy Staff; Council Leads | 32h |  |
| 378 | 1.9.3.2.35 | GNSO Council - Leadership Meetings | manual | 2d | 2023-05-18 | 2023-05-19 |  |  |  | start no earlier than 2023-05-18 | Policy Staff; Council Leads | 32h |  |
| 379 | 1.9.3.2.36 | GNSO Council - Leadership Meetings | manual | 2d | 2023-06-21 | 2023-06-22 |  |  |  | start no earlier than 2023-06-21 | Policy Staff; Council Leads | 32h |  |
| 380 | 1.9.3.2.37 | GNSO Council - Leadership Meetings | manual | 2d | 2023-07-20 | 2023-07-21 |  |  |  | start no earlier than 2023-07-20 | Policy Staff; Council Leads | 32h |  |
| 381 | 1.9.3.2.38 | GNSO Council - Leadership Meetings | manual | 2d | 2023-08-17 | 2023-08-18 |  |  |  | start no earlier than 2023-08-17 | Policy Staff; Council Leads | 32h |  |
| 382 | 1.9.3.2.39 | GNSO Council - Leadership Meetings | manual | 2d | 2023-09-21 | 2023-09-22 |  |  |  | start no earlier than 2023-09-21 | Policy Staff; Council Leads | 32h |  |
| 383 | 1.9.3.2.40 | GNSO Council - Leadership Meetings | manual | 2d | 2023-10-18 | 2023-10-19 |  |  |  | start no earlier than 2023-10-18 | Policy Staff; Council Leads | 32h |  |
| 384 | 1.9.3.2.41 | GNSO Council - Leadership Meetings | manual | 2d | 2023-11-16 | 2023-11-17 |  |  |  | start no earlier than 2023-11-16 | Policy Staff; Council Leads | 32h |  |
| 385 | 1.9.3.2.42 | GNSO Council - Leadership Meetings | manual | 2d | 2023-12-14 | 2023-12-15 |  |  |  | start no earlier than 2023-12-14 | Policy Staff; Council Leads | 32h |  |
| 386 | 1.9.3.2.43 | GNSO Council - Leadership Meetings | manual | 2d | 2024-01-18 | 2024-01-19 |  |  |  | start no earlier than 2024-01-18 | Policy Staff; Council Leads | 32h |  |
| 387 | 1.9.3.2.44 | GNSO Council - Leadership Meetings | manual | 2d | 2024-02-15 | 2024-02-16 |  |  |  | start no earlier than 2024-02-15 | Policy Staff; Council Leads | 32h |  |
| 388 | 1.9.3.2.45 | GNSO Council - Leadership Meetings | manual | 2d | 2024-03-20 | 2024-03-21 |  |  |  | start no earlier than 2024-03-20 | Policy Staff; Council Leads | 32h |  |
| 389 | 1.9.3.2.46 | GNSO Council - Leadership Meetings | manual | 2d | 2024-04-18 | 2024-04-19 |  |  |  | start no earlier than 2024-04-18 | Policy Staff; Council Leads | 32h |  |
| 390 | 1.9.3.2.47 | GNSO Council - Leadership Meetings | manual | 2d | 2024-05-16 | 2024-05-17 |  |  |  | start no earlier than 2024-05-16 | Policy Staff; Council Leads | 32h |  |
| 391 | 1.9.3.2.48 | GNSO Council - Leadership Meetings | manual | 2d | 2024-06-19 | 2024-06-20 |  |  |  | start no earlier than 2024-06-19 | Policy Staff; Council Leads | 32h |  |
| 392 | 1.9.3.2.49 | GNSO Council - Leadership Meetings | manual | 2d | 2024-07-18 | 2024-07-19 |  |  |  | start no earlier than 2024-07-18 | Policy Staff; Council Leads | 32h |  |
| 393 | 1.9.3.2.50 | GNSO Council - Leadership Meetings | manual | 2d | 2024-08-15 | 2024-08-16 |  |  |  | start no earlier than 2024-08-15 | Policy Staff; Council Leads | 32h |  |
| 394 | 1.9.3.2.51 | GNSO Council - Leadership Meetings | manual | 2d | 2024-09-19 | 2024-09-20 |  |  |  | start no earlier than 2024-09-19 | Policy Staff; Council Leads | 32h |  |
| 395 | 1.9.3.2.52 | GNSO Council - Leadership Meetings | manual | 2d | 2024-10-23 | 2024-10-24 |  |  |  | start no earlier than 2024-10-23 | Policy Staff; Council Leads | 32h |  |
| 396 | 1.9.3.2.53 | GNSO Council - Leadership Meetings | manual | 2d | 2024-11-14 | 2024-11-15 |  |  |  | start no earlier than 2024-11-14 | Policy Staff; Council Leads | 32h |  |
| 397 | 1.9.3.2.54 | GNSO Council - Leadership Meetings | manual | 2d | 2024-12-12 | 2024-12-13 |  |  |  | start no earlier than 2024-12-12 | Policy Staff; Council Leads | 32h |  |
| 398 | 1.9.3.2.55 | GNSO Council - Leadership Meetings | manual | 2d | 2025-01-16 | 2025-01-17 |  |  |  | start no earlier than 2025-01-16 | Policy Staff; Council Leads | 32h |  |
| 399 | 1.9.3.2.56 | GNSO Council - Leadership Meetings | manual | 2d | 2025-02-13 | 2025-02-14 |  |  |  | start no earlier than 2025-02-13 | Policy Staff; Council Leads | 32h |  |
| 400 | 1.9.3.2.57 | GNSO Council - Leadership Meetings | manual | 2d | 2025-03-19 | 2025-03-20 |  |  |  | start no earlier than 2025-03-19 | Policy Staff; Council Leads | 32h |  |
| 401 | 1.9.3.2.58 | GNSO Council - Leadership Meetings | manual | 2d | 2025-04-17 | 2025-04-18 |  |  |  | start no earlier than 2025-04-17 | Policy Staff; Council Leads | 32h |  |
| 402 | 1.9.3.2.59 | GNSO Council - Leadership Meetings | manual | 2d | 2025-05-15 | 2025-05-16 |  |  |  | start no earlier than 2025-05-15 | Policy Staff; Council Leads | 32h |  |
| 403 | 1.9.3.2.60 | GNSO Council - Leadership Meetings | manual | 2d | 2025-06-18 | 2025-06-19 |  |  |  | start no earlier than 2025-06-18 | Policy Staff; Council Leads | 32h |  |
| 404 | 1.9.3.2.61 | GNSO Council - Leadership Meetings | manual | 2d | 2025-07-17 | 2025-07-18 |  |  |  | start no earlier than 2025-07-17 | Policy Staff; Council Leads | 32h |  |
| 405 | 1.9.3.2.62 | GNSO Council - Leadership Meetings | manual | 2d | 2025-08-21 | 2025-08-22 |  |  |  | start no earlier than 2025-08-21 | Policy Staff; Council Leads | 32h |  |
| 406 | 1.9.3.2.63 | GNSO Council - Leadership Meetings | manual | 2d | 2025-09-18 | 2025-09-19 |  |  |  | start no earlier than 2025-09-18 | Policy Staff; Council Leads | 32h |  |
| 407 | 1.9.3.2.64 | GNSO Council - Leadership Meetings | manual | 2d | 2025-10-22 | 2025-10-23 |  |  |  | start no earlier than 2025-10-22 | Policy Staff; Council Leads | 32h |  |
| 408 | 1.9.3.2.65 | GNSO Council - Leadership Meetings | manual | 2d | 2025-11-13 | 2025-11-14 |  |  |  | start no earlier than 2025-11-13 | Policy Staff; Council Leads | 32h |  |

| ID | WBS | Task | Type | Duration | Start | Finish | Complete | Remaining | Total slack | Constraint | Resources | Work | Actual work |
| --- | --- | --- | --- | --- | --- | --- | --- | --- | --- | --- | --- | --- | --- |
| 409 | 1.9.3.2.66 | GNSO Council - Leadership Meetings | manual | 2d | 2025-12-18 | 2025-12-19 |  |  |  | start no earlier than 2025-12-18 | Policy Staff; Council Leads | 32h |  |
| 410 | 1.9.3.2.67 | GNSO Council - Leadership Meetings | manual | 2d | 2026-01-15 | 2026-01-16 |  |  |  | start no earlier than 2026-01-15 | Policy Staff; Council Leads | 32h |  |
| 411 | 1.9.3.2.68 | GNSO Council - Leadership Meetings | manual | 2d | 2026-02-19 | 2026-02-20 |  |  |  | start no earlier than 2026-02-19 | Policy Staff; Council Leads | 32h |  |
| 412 | 1.9.3.2.69 | GNSO Council - Leadership Meetings | manual | 2d | 2026-03-18 | 2026-03-19 |  |  |  | start no earlier than 2026-03-18 | Policy Staff; Council Leads | 32h |  |
| 413 | 1.9.3.2.70 | GNSO Council - Leadership Meetings | manual | 2d | 2026-04-16 | 2026-04-17 |  |  |  | start no earlier than 2026-04-16 | Policy Staff; Council Leads | 32h |  |
| 414 | 1.9.3.2.71 | GNSO Council - Leadership Meetings | manual | 2d | 2026-05-14 | 2026-05-15 |  |  |  | start no earlier than 2026-05-14 | Policy Staff; Council Leads | 32h |  |
| 415 | 1.9.3.2.72 | GNSO Council - Leadership Meetings | manual | 2d | 2026-06-17 | 2026-06-18 |  |  |  | start no earlier than 2026-06-17 | Policy Staff; Council Leads | 32h |  |
| 416 | 1.9.3.3 | **GNSO Council - Action Items** |  | 1553d | 2020-07-13 A | 2026-06-17 | 8% | 1423.58d | 0d |  |  | 1152h | 96h |
| 417 | 1.9.3.3.1 | GNSO Council - Action Items | manual | 1d | 2020-07-13 A | 2020-07-13 A | 100% |  |  | start no earlier than 2020-07-13 | Council Leads; Policy Staff | 16h | 16h |
| 418 | 1.9.3.3.2 | GNSO Council - Action Items | manual | 1d | 2020-08-10 A | 2020-08-10 A | 100% |  |  | start no earlier than 2020-08-10 | Council Leads; Policy Staff | 16h | 16h |
| 419 | 1.9.3.3.3 | GNSO Council - Action Items | manual | 1d | 2020-09-14 A | 2020-09-14 A | 100% |  |  | start no earlier than 2020-09-14 | Council Leads; Policy Staff | 16h | 16h |
| 420 | 1.9.3.3.4 | GNSO Council - Action Items | manual | 1d | 2020-10-12 A | 2020-10-12 A | 100% |  |  | start no earlier than 2020-10-12 | Council Leads; Policy Staff | 16h | 16h |
| 421 | 1.9.3.3.5 | GNSO Council - Action Items | manual | 1d | 2020-11-09 A | 2020-11-09 A | 100% |  |  | start no earlier than 2020-11-09 | Council Leads; Policy Staff | 16h | 16h |
| 422 | 1.9.3.3.6 | GNSO Council - Action Items | manual | 1d | 2020-12-14 A | 2020-12-14 A | 100% |  |  | start no earlier than 2020-12-14 | Council Leads; Policy Staff | 16h | 16h |
| 423 | 1.9.3.3.7 | GNSO Council - Action Items | manual | 1d | 2021-01-11 | 2021-01-11 |  |  |  | start no earlier than 2021-01-11 | Council Leads; Policy Staff | 16h |  |
| 424 | 1.9.3.3.8 | GNSO Council - Action Items | manual | 1d | 2021-02-08 | 2021-02-08 |  |  |  | start no earlier than 2021-02-08 | Council Leads; Policy Staff | 16h |  |
| 425 | 1.9.3.3.9 | GNSO Council - Action Items | manual | 1d | 2021-03-08 | 2021-03-08 |  |  |  | start no earlier than 2021-03-08 | Council Leads; Policy Staff | 16h |  |
| 426 | 1.9.3.3.10 | GNSO Council - Action Items | manual | 1d | 2021-04-12 | 2021-04-12 |  |  |  | start no earlier than 2021-04-12 | Council Leads; Policy Staff | 16h |  |
| 427 | 1.9.3.3.11 | GNSO Council - Action Items | manual | 1d | 2021-05-10 | 2021-05-10 |  |  |  | start no earlier than 2021-05-10 | Council Leads; Policy Staff | 16h |  |
| 428 | 1.9.3.3.12 | GNSO Council - Action Items | manual | 1d | 2021-06-14 | 2021-06-14 |  |  |  | start no earlier than 2021-06-14 | Council Leads; Policy Staff | 16h |  |
| 429 | 1.9.3.3.13 | GNSO Council - Action Items | manual | 1d | 2021-07-12 | 2021-07-12 |  |  |  | start no earlier than 2021-07-12 | Council Leads; Policy Staff | 16h |  |
| 430 | 1.9.3.3.14 | GNSO Council - Action Items | manual | 1d | 2021-08-09 | 2021-08-09 |  |  |  | start no earlier than 2021-08-09 | Council Leads; Policy Staff | 16h |  |
| 431 | 1.9.3.3.15 | GNSO Council - Action Items | manual | 1d | 2021-09-13 | 2021-09-13 |  |  |  | start no earlier than 2021-09-13 | Council Leads; Policy Staff | 16h |  |
| 432 | 1.9.3.3.16 | GNSO Council - Action Items | manual | 1d | 2021-10-11 | 2021-10-11 |  |  |  | start no earlier than 2021-10-11 | Council Leads; Policy Staff | 16h |  |
| 433 | 1.9.3.3.17 | GNSO Council - Action Items | manual | 1d | 2021-11-08 | 2021-11-08 |  |  |  | start no earlier than 2021-11-08 | Council Leads; Policy Staff | 16h |  |
| 434 | 1.9.3.3.18 | GNSO Council - Action Items | manual | 1d | 2021-12-13 | 2021-12-13 |  |  |  | start no earlier than 2021-12-13 | Council Leads; Policy Staff | 16h |  |
| 435 | 1.9.3.3.19 | GNSO Council - Action Items | manual | 1d | 2022-01-20 | 2022-01-20 |  |  |  | start no earlier than 2022-01-20 | Council; Policy Staff | 16h |  |
| 436 | 1.9.3.3.20 | GNSO Council - Action Items | manual | 1d | 2022-02-17 | 2022-02-17 |  |  |  | start no earlier than 2022-02-17 | Council; Policy Staff | 16h |  |
| 437 | 1.9.3.3.21 | GNSO Council - Action Items | manual | 1d | 2022-03-24 | 2022-03-24 |  |  |  | start no earlier than 2022-03-24 | Council; Policy Staff | 16h |  |
| 438 | 1.9.3.3.22 | GNSO Council - Action Items | manual | 1d | 2022-04-21 | 2022-04-21 |  |  |  | start no earlier than 2022-04-21 | Council; Policy Staff | 16h |  |
| 439 | 1.9.3.3.23 | GNSO Council - Action Items | manual | 1d | 2022-05-19 | 2022-05-19 |  |  |  | start no earlier than 2022-05-19 | Council; Policy Staff | 16h |  |
| 440 | 1.9.3.3.24 | GNSO Council - Action Items | manual | 1d | 2022-06-22 | 2022-06-22 |  |  |  | start no earlier than 2022-06-22 | Council; Policy Staff | 16h |  |
| 441 | 1.9.3.3.25 | GNSO Council - Action Items | manual | 1d | 2022-07-21 | 2022-07-21 |  |  |  | start no earlier than 2022-07-21 | Council; Policy Staff | 16h |  |
| 442 | 1.9.3.3.26 | GNSO Council - Action Items | manual | 1d | 2022-08-18 | 2022-08-18 |  |  |  | start no earlier than 2022-08-18 | Council; Policy Staff | 16h |  |
| 443 | 1.9.3.3.27 | GNSO Council - Action Items | manual | 1d | 2022-09-22 | 2022-09-22 |  |  |  | start no earlier than 2022-09-22 | Council; Policy Staff | 16h |  |
| 444 | 1.9.3.3.28 | GNSO Council - Action Items | manual | 1d | 2022-10-19 | 2022-10-19 |  |  |  | start no earlier than 2022-10-19 | Council; Policy Staff | 16h |  |
| 445 | 1.9.3.3.29 | GNSO Council - Action Items | manual | 1d | 2022-11-17 | 2022-11-17 |  |  |  | start no earlier than 2022-11-17 | Council; Policy Staff | 16h |  |
| 446 | 1.9.3.3.30 | GNSO Council - Action Items | manual | 1d | 2022-12-15 | 2022-12-15 |  |  |  | start no earlier than 2022-12-15 | Council; Policy Staff | 16h |  |
| 447 | 1.9.3.3.31 | GNSO Council - Action Items | manual | 1d | 2023-01-19 | 2023-01-19 |  |  |  | start no earlier than 2023-01-19 | Council; Policy Staff | 16h |  |
| 448 | 1.9.3.3.32 | GNSO Council - Action Items | manual | 1d | 2023-02-16 | 2023-02-16 |  |  |  | start no earlier than 2023-02-16 | Council; Policy Staff | 16h |  |
| 449 | 1.9.3.3.33 | GNSO Council - Action Items | manual | 1d | 2023-03-22 | 2023-03-22 |  |  |  | start no earlier than 2023-03-22 | Council; Policy Staff | 16h |  |
| 450 | 1.9.3.3.34 | GNSO Council - Action Items | manual | 1d | 2023-04-20 | 2023-04-20 |  |  |  | start no earlier than 2023-04-20 | Council; Policy Staff | 16h |  |
| 451 | 1.9.3.3.35 | GNSO Council - Action Items | manual | 1d | 2023-05-18 | 2023-05-18 |  |  |  | start no earlier than 2023-05-18 | Council; Policy Staff | 16h |  |
| 452 | 1.9.3.3.36 | GNSO Council - Action Items | manual | 1d | 2023-06-21 | 2023-06-21 |  |  |  | start no earlier than 2023-06-21 | Council; Policy Staff | 16h |  |
| 453 | 1.9.3.3.37 | GNSO Council - Action Items | manual | 1d | 2023-07-20 | 2023-07-20 |  |  |  | start no earlier than 2023-07-20 | Council; Policy Staff | 16h |  |
| 454 | 1.9.3.3.38 | GNSO Council - Action Items | manual | 1d | 2023-08-17 | 2023-08-17 |  |  |  | start no earlier than 2023-08-17 | Council; Policy Staff | 16h |  |
| 455 | 1.9.3.3.39 | GNSO Council - Action Items | manual | 1d | 2023-09-21 | 2023-09-21 |  |  |  | start no earlier than 2023-09-21 | Council; Policy Staff | 16h |  |
| 456 | 1.9.3.3.40 | GNSO Council - Action Items | manual | 1d | 2023-10-18 | 2023-10-18 |  |  |  | start no earlier than 2023-10-18 | Council; Policy Staff | 16h |  |
| 457 | 1.9.3.3.41 | GNSO Council - Action Items | manual | 1d | 2023-11-16 | 2023-11-16 |  |  |  | start no earlier than 2023-11-16 | Council; Policy Staff | 16h |  |
| 458 | 1.9.3.3.42 | GNSO Council - Action Items | manual | 1d | 2023-12-14 | 2023-12-14 |  |  |  | start no earlier than 2023-12-14 | Council; Policy Staff | 16h |  |
| 459 | 1.9.3.3.43 | GNSO Council - Action Items | manual | 1d | 2024-01-18 | 2024-01-18 |  |  |  | start no earlier than 2024-01-18 | Council; Policy Staff | 16h |  |
| 460 | 1.9.3.3.44 | GNSO Council - Action Items | manual | 1d | 2024-02-15 | 2024-02-15 |  |  |  | start no earlier than 2024-02-15 | Council; Policy Staff | 16h |  |
| 461 | 1.9.3.3.45 | GNSO Council - Action Items | manual | 1d | 2024-03-20 | 2024-03-20 |  |  |  | start no earlier than 2024-03-20 | Council; Policy Staff | 16h |  |
| 462 | 1.9.3.3.46 | GNSO Council - Action Items | manual | 1d | 2024-04-18 | 2024-04-18 |  |  |  | start no earlier than 2024-04-18 | Council; Policy Staff | 16h |  |
| 463 | 1.9.3.3.47 | GNSO Council - Action Items | manual | 1d | 2024-05-16 | 2024-05-16 |  |  |  | start no earlier than 2024-05-16 | Council; Policy Staff | 16h |  |
| 464 | 1.9.3.3.48 | GNSO Council - Action Items | manual | 1d | 2024-06-19 | 2024-06-19 |  |  |  | start no earlier than 2024-06-19 | Council; Policy Staff | 16h |  |
| 465 | 1.9.3.3.49 | GNSO Council - Action Items | manual | 1d | 2024-07-18 | 2024-07-18 |  |  |  | start no earlier than 2024-07-18 | Council; Policy Staff | 16h |  |
| 466 | 1.9.3.3.50 | GNSO Council - Action Items | manual | 1d | 2024-08-15 | 2024-08-15 |  |  |  | start no earlier than 2024-08-15 | Council; Policy Staff | 16h |  |
| 467 | 1.9.3.3.51 | GNSO Council - Action Items | manual | 1d | 2024-09-19 | 2024-09-19 |  |  |  | start no earlier than 2024-09-19 | Council; Policy Staff | 16h |  |
| 468 | 1.9.3.3.52 | GNSO Council - Action Items | manual | 1d | 2024-10-23 | 2024-10-23 |  |  |  | start no earlier than 2024-10-23 | Council; Policy Staff | 16h |  |
| 469 | 1.9.3.3.53 | GNSO Council - Action Items | manual | 1d | 2024-11-14 | 2024-11-14 |  |  |  | start no earlier than 2024-11-14 | Council; Policy Staff | 16h |  |
| 470 | 1.9.3.3.54 | GNSO Council - Action Items | manual | 1d | 2024-12-12 | 2024-12-12 |  |  |  | start no earlier than 2024-12-12 | Council; Policy Staff | 16h |  |
| 471 | 1.9.3.3.55 | GNSO Council - Action Items | manual | 1d | 2025-01-16 | 2025-01-16 |  |  |  | start no earlier than 2025-01-16 | Council; Policy Staff | 16h |  |
| 472 | 1.9.3.3.56 | GNSO Council - Action Items | manual | 1d | 2025-02-13 | 2025-02-13 |  |  |  | start no earlier than 2025-02-13 | Council; Policy Staff | 16h |  |
| 473 | 1.9.3.3.57 | GNSO Council - Action Items | manual | 1d | 2025-03-19 | 2025-03-19 |  |  |  | start no earlier than 2025-03-19 | Council; Policy Staff | 16h |  |
| 474 | 1.9.3.3.58 | GNSO Council - Action Items | manual | 1d | 2025-04-17 | 2025-04-17 |  |  |  | start no earlier than 2025-04-17 | Council; Policy Staff | 16h |  |
| 475 | 1.9.3.3.59 | GNSO Council - Action Items | manual | 1d | 2025-05-15 | 2025-05-15 |  |  |  | start no earlier than 2025-05-15 | Council; Policy Staff | 16h |  |
| 476 | 1.9.3.3.60 | GNSO Council - Action Items | manual | 1d | 2025-06-18 | 2025-06-18 |  |  |  | start no earlier than 2025-06-18 | Council; Policy Staff | 16h |  |
| 477 | 1.9.3.3.61 | GNSO Council - Action Items | manual | 1d | 2025-07-17 | 2025-07-17 |  |  |  | start no earlier than 2025-07-17 | Council; Policy Staff | 16h |  |
| 478 | 1.9.3.3.62 | GNSO Council - Action Items | manual | 1d | 2025-08-21 | 2025-08-21 |  |  |  | start no earlier than 2025-08-21 | Council; Policy Staff | 16h |  |

| ID | WBS | Task | Type | Duration | Start | Finish | Predecessors | Complete | Remaining | Total slack | Free slack | Constraint | Resources | Work | Actual work |
| --- | --- | --- | --- | --- | --- | --- | --- | --- | --- | --- | --- | --- | --- | --- | --- |
| 479 | 1.9.3.3.63 | GNSO Council - Action Items | manual | 1d | 2025-09-18 | 2025-09-18 |  |  |  |  |  | start no earlier than 2025-09-18 | Council; Policy Staff | 16h |  |
| 480 | 1.9.3.3.64 | GNSO Council - Action Items | manual | 1d | 2025-10-22 | 2025-10-22 |  |  |  |  |  | start no earlier than 2025-10-22 | Council; Policy Staff | 16h |  |
| 481 | 1.9.3.3.65 | GNSO Council - Action Items | manual | 1d | 2025-11-13 | 2025-11-13 |  |  |  |  |  | start no earlier than 2025-11-13 | Council; Policy Staff | 16h |  |
| 482 | 1.9.3.3.66 | GNSO Council - Action Items | manual | 1d | 2025-12-18 | 2025-12-18 |  |  |  |  |  | start no earlier than 2025-12-18 | Council; Policy Staff | 16h |  |
| 483 | 1.9.3.3.67 | GNSO Council - Action Items | manual | 1d | 2026-01-15 | 2026-01-15 |  |  |  |  |  | start no earlier than 2026-01-15 | Council; Policy Staff | 16h |  |
| 484 | 1.9.3.3.68 | GNSO Council - Action Items | manual | 1d | 2026-02-19 | 2026-02-19 |  |  |  |  |  | start no earlier than 2026-02-19 | Council; Policy Staff | 16h |  |
| 485 | 1.9.3.3.69 | GNSO Council - Action Items | manual | 1d | 2026-03-18 | 2026-03-18 |  |  |  |  |  | start no earlier than 2026-03-18 | Council; Policy Staff | 16h |  |
| 486 | 1.9.3.3.70 | GNSO Council - Action Items | manual | 1d | 2026-04-16 | 2026-04-16 |  |  |  |  |  | start no earlier than 2026-04-16 | Council; Policy Staff | 16h |  |
| 487 | 1.9.3.3.71 | GNSO Council - Action Items | manual | 1d | 2026-05-14 | 2026-05-14 |  |  |  |  |  | start no earlier than 2026-05-14 | Council; Policy Staff | 16h |  |
| 488 | 1.9.3.3.72 | GNSO Council - Action Items | manual | 1d | 2026-06-17 | 2026-06-17 |  |  |  |  |  | start no earlier than 2026-06-17 | Council; Policy Staff | 16h |  |
| 489 | 1.9.3.4 | **GNSO Standing Committee on Budget and Operations** |  | 1123d | 2020-11-02 A | 2025-02-12 |  | 6% | 1055.62d | 359d |  |  |  | 6000h | 360h |
| 490 | 1.9.3.4.1 | **2020-2021** |  | 75d | 2020-11-02 A | 2021-02-12 |  | 30% | 52.5d | 1407d |  |  |  | 1200h | 360h |
| 491 | 1.9.3.4.1.1 | Refresh roster and confirm Chair | manual | 15d | 2020-11-02 A | 2020-11-20 A |  | 100% |  |  |  |  | Policy Staff; Council | 240h | 240h |
| 492 | 1.9.3.4.1.2 | Evaluate fiscal year budget and planning documents |  | 50d | 2020-11-23 A | 2021-01-29 | 491 | 15% | 42.5d | 1407d | 0d |  | Council; Policy Staff | 800h | 120h |
| 493 | 1.9.3.4.1.3 | Complete draft of comments for Council consideration and submit |  | 10d | 2021-02-01 | 2021-02-12 | 492 |  |  | 1407d |  |  | Council; Policy Staff | 160h |  |
| 494 | 1.9.3.4.2 | **2021-2022** |  | 75d | 2021-11-01 | 2022-02-11 |  |  |  | 0d |  |  |  | 1200h |  |
| 495 | 1.9.3.4.2.1 | Refresh roster and confirm Chair | manual | 15d | 2021-11-01 | 2021-11-19 |  |  |  |  |  |  | Policy Staff; Council | 240h |  |
| 496 | 1.9.3.4.2.2 | Evaluate fiscal year budget and planning documents |  | 50d | 2021-11-22 | 2022-01-28 | 495 |  |  | 1145d | 0d |  | Council; Policy Staff | 800h |  |
| 497 | 1.9.3.4.2.3 | Complete draft of comments for Council consideration and submit |  | 10d | 2022-01-31 | 2022-02-11 | 496 |  |  | 1145d |  |  | Council; Policy Staff | 160h |  |
| 498 | 1.9.3.4.3 | **2022-2023** |  | 75d | 2022-11-01 | 2023-02-13 |  |  |  | 0d |  |  |  | 1200h |  |
| 499 | 1.9.3.4.3.1 | Refresh roster and confirm Chair | manual | 15d | 2022-11-01 | 2022-11-21 |  |  |  |  |  |  | Policy Staff; Council | 240h |  |
| 500 | 1.9.3.4.3.2 | Evaluate fiscal year budget and planning documents |  | 50d | 2022-11-22 | 2023-01-30 | 499 |  |  | 884d | 0d |  | Council; Policy Staff | 800h |  |
| 501 | 1.9.3.4.3.3 | Complete draft of comments for Council consideration and submit |  | 10d | 2023-01-31 | 2023-02-13 | 500 |  |  | 884d |  |  | Council; Policy Staff | 160h |  |
| 502 | 1.9.3.4.4 | **2023-2024** |  | 75d | 2023-11-01 | 2024-02-13 |  |  |  | 0d |  |  |  | 1200h |  |
| 503 | 1.9.3.4.4.1 | Refresh roster and confirm Chair | manual | 15d | 2023-11-01 | 2023-11-21 |  |  |  |  |  |  | Policy Staff; Council | 240h |  |
| 504 | 1.9.3.4.4.2 | Evaluate fiscal year budget and planning documents |  | 50d | 2023-11-22 | 2024-01-30 | 503 |  |  | 621d | 0d |  | Council; Policy Staff | 800h |  |
| 505 | 1.9.3.4.4.3 | Complete draft of comments for Council consideration and submit |  | 10d | 2024-01-31 | 2024-02-13 | 504 |  |  | 621d |  |  | Council; Policy Staff | 160h |  |

| ID | WBS | Task | Type | Duration | Start | Finish | Predecessors | Complete | Remaining | Total slack | Free slack | Constraint | Resources | Work | Actual work |
| --- | --- | --- | --- | --- | --- | --- | --- | --- | --- | --- | --- | --- | --- | --- | --- |
| 506 | 1.9.3.4.5 | **2024-2025** |  | 75d | 2024-11-01 | 2025-02-12 |  |  |  | 0d |  |  |  | 1200h |  |
| 507 | 1.9.3.4.5.1 | Refresh roster and confirm Chair | manual | 15d | 2024-11-01 | 2024-11-21 |  |  |  |  |  |  | Policy Staff; Council | 240h |  |
| 508 | 1.9.3.4.5.2 | Evaluate fiscal year budget and planning documents |  | 50d | 2024-11-22 | 2025-01-29 | 507 |  |  | 359d | 0d |  | Council; Policy Staff | 800h |  |
| 509 | 1.9.3.4.5.3 | Complete draft of comments for Council consideration and submit |  | 10d | 2025-01-30 | 2025-02-12 | 508 |  |  | 359d |  |  | Council; Policy Staff | 160h |  |
| 510 | 1.9.3.5 | **GNSO Standing Selection Committee** |  | 1301d | 2020-07-01 A | 2025-06-18 |  | 18% | 1069.22d | 0d |  |  |  | 20800h | 3705.6h |
| 511 | 1.9.3.5.1 | SSC fill positions as assigned | manual | 1300d | 2020-07-01 A | 2025-06-18 |  | 18% | 1068.4d |  |  |  | SSC; Policy Staff | 20800h | 3705.6h |
| 512 | 1.9.3.6 | **Strategic Planning Session** |  | 1142d | 2020-10-01 A | 2025-02-07 |  | 7% | 1065.21d | 362d |  |  |  | 11184h | 752h |
| 513 | 1.9.3.6.1 | **2020-2021** |  | 52d | 2020-10-01 A | 2020-12-11 |  | 80% | 10.58d | 1452d |  |  |  | 944h | 752h |
| 514 | 1.9.3.6.1.1 | Establish and manage travel arrangements | manual | 1d | 2020-10-01 A | 2020-10-01 A |  | 100% |  |  |  |  | Council Leads; Policy Staff | 16h | 16h |
| 515 | 1.9.3.6.1.2 | Develop plan, topics, and materials for deliberation | manual | 30d | 2020-10-01 A | 2020-11-11 A |  | 100% |  |  |  |  | Council Leads; Policy Staff | 480h | 480h |
| 516 | 1.9.3.6.1.3 | Conduct planning session |  | 13d | 2020-11-02 A | 2020-11-23 A | 515 | 100% |  |  |  |  | Council; Policy Staff | 208h | 208h |
| 517 | 1.9.3.6.1.4 | Develop post planning session report |  | 15d | 2020-11-23 A | 2020-12-11 | 516 | 20% | 12d | 1452d |  |  | Council Leads; Policy Staff | 240h | 48h |
| 518 | 1.9.3.6.2 | **2021-2022** |  | 92d | 2021-10-01 | 2022-02-04 |  |  |  | 0d |  |  |  | 2560h |  |
| 519 | 1.9.3.6.2.1 | Establish and manage travel arrangements | manual | 75d | 2021-10-01 | 2022-01-12 |  |  |  |  |  |  | Council Leads; Policy Staff | 1200h |  |
| 520 | 1.9.3.6.2.2 | Develop plan, topics, and materials for deliberation | manual | 65d | 2021-10-01 | 2021-12-29 |  |  |  |  |  |  | Council Leads; Policy Staff | 1040h |  |
| 521 | 1.9.3.6.2.3 | Conduct planning session |  | 5d | 2022-01-10 | 2022-01-14 | 520 |  |  | 1150d | 0d | start no earlier than 2022-01-10 | Council; Policy Staff | 80h |  |
| 522 | 1.9.3.6.2.4 | Develop post planning session report |  | 15d | 2022-01-17 | 2022-02-04 | 521 |  |  | 1150d |  |  | Council Leads; Policy Staff | 240h |  |
| 523 | 1.9.3.6.3 | **2022-2023** |  | 90d | 2022-10-01 | 2023-02-03 |  |  |  | 0d |  |  |  | 2560h |  |
| 524 | 1.9.3.6.3.1 | Establish and manage travel arrangements | manual | 75d | 2022-10-01 | 2023-01-12 |  |  |  |  |  |  | Council Leads; Policy Staff | 1200h |  |
| 525 | 1.9.3.6.3.2 | Develop plan, topics, and materials for deliberation | manual | 65d | 2022-10-01 | 2022-12-29 |  |  |  |  |  |  | Council Leads; Policy Staff | 1040h |  |
| 526 | 1.9.3.6.3.3 | Conduct planning session |  | 5d | 2023-01-09 | 2023-01-13 | 525 |  |  | 890d | 0d | start no earlier than 2023-01-09 | Council; Policy Staff | 80h |  |
| 527 | 1.9.3.6.3.4 | Develop post planning session report |  | 15d | 2023-01-16 | 2023-02-03 | 526 |  |  | 890d |  |  | Council Leads; Policy Staff | 240h |  |
| 528 | 1.9.3.6.4 | **2023-2024** |  | 95d | 2023-10-01 | 2024-02-09 |  |  |  | 0d |  |  |  | 2560h |  |
| 529 | 1.9.3.6.4.1 | Establish and manage travel arrangements | manual | 75d | 2023-10-01 | 2024-01-11 |  |  |  |  |  |  | Council Leads; Policy Staff | 1200h |  |
| 530 | 1.9.3.6.4.2 | Develop plan, topics, and materials for deliberation | manual | 65d | 2023-10-01 | 2023-12-28 |  |  |  |  |  |  | Council Leads; Policy Staff | 1040h |  |
| 531 | 1.9.3.6.4.3 | Conduct planning session |  | 5d | 2024-01-15 | 2024-01-19 | 530 |  |  | 623d | 0d | start no earlier than 2024-01-15 | Council; Policy Staff | 80h |  |
| 532 | 1.9.3.6.4.4 | Develop post planning session report |  | 15d | 2024-01-22 | 2024-02-09 | 531 |  |  | 623d |  |  | Council Leads; Policy Staff | 240h |  |

| ID | WBS | Task | Type | Duration | Start | Finish | Predecessors | Complete | Remaining | Total slack | Free slack | Constraint | Resources | Work | Actual work |
| --- | --- | --- | --- | --- | --- | --- | --- | --- | --- | --- | --- | --- | --- | --- | --- |
| 533 | 1.9.3.6.5 | **2024-2025** |  | 95d | 2024-10-01 | 2025-02-07 |  |  |  | 0d |  |  |  | 2560h |  |
| 534 | 1.9.3.6.5.1 | Establish and manage travel arrangements | manual | 75d | 2024-10-01 | 2025-01-10 |  |  |  |  |  |  | Council Leads; Policy Staff | 1200h |  |
| 535 | 1.9.3.6.5.2 | Develop plan, topics, and materials for deliberation | manual | 65d | 2024-10-01 | 2024-12-27 |  |  |  |  |  |  | Council Leads; Policy Staff | 1040h |  |
| 536 | 1.9.3.6.5.3 | Conduct planning session |  | 5d | 2025-01-13 | 2025-01-17 | 535 |  |  | 362d | 0d | start no earlier than 2025-01-13 | Council; Policy Staff | 80h |  |
| 537 | 1.9.3.6.5.4 | Develop post planning session report |  | 15d | 2025-01-20 | 2025-02-07 | 536 |  |  | 362d |  |  | Council Leads; Policy Staff | 240h |  |
| 538 | 1.9.3.7 | **ICANN Meeting Planning, Meeting, Respond to GAC Advice** |  | 1570d | 2020-07-01 A | 2026-06-30 |  | 6% | 1474.08d | 0d |  |  |  | 32800h | 1960h |
| 539 | 1.9.3.7.1 | **ICANN69** |  | 97d | 2020-07-01 A | 2020-11-12 A |  | 100% |  |  |  |  |  | 1960h | 1960h |
| 540 | 1.9.3.7.1.1 | Meeting Planning |  | 75d | 2020-07-01 A | 2020-10-13 A |  | 100% |  |  |  |  | Council Leads; Policy Staff | 1200h | 1200h |
| 541 | 1.9.3.7.1.2 | ICANN Meeting |  | 5d | 2020-10-17 A | 2020-10-22 A | 540 | 100% |  |  |  |  | Board; Contracted Parties; Council; Council Leads; EC Admin; EC Rep; Finance Staff; GDS Staff; IRT; Legal Staff; Policy Staff; SSC; Working Group | 520h | 520h |
| 542 | 1.9.3.7.1.3 | Respond to GAC Advice |  | 15d | 2020-10-23 A | 2020-11-12 A | 541 | 100% |  |  |  |  | Council; Policy Staff | 240h | 240h |
| 543 | 1.9.3.7.2 | **ICANN70** |  | 99d | 2020-12-01 | 2021-04-15 |  |  |  | 1362d |  |  |  | 1960h |  |
| 544 | 1.9.3.7.2.1 | Meeting Planning |  | 75d | 2020-12-01 | 2021-03-15 |  |  |  | 1366d | 4d | start no earlier than 2020-12-01 | Council Leads; Policy Staff | 1200h |  |
| 545 | 1.9.3.7.2.2 | ICANN Meeting |  | 5d | 2021-03-20 | 2021-03-25 | 544 |  |  | 1362d | 0d | start no earlier than 2021-03-20 | Board; Contracted Parties; Council; Council Leads; EC Admin; EC Rep; Finance Staff; GDS Staff; IRT; Legal Staff; Policy Staff; SSC; Working Group | 520h |  |
| 546 | 1.9.3.7.2.3 | Respond to GAC Advice |  | 15d | 2021-03-26 | 2021-04-15 | 545 |  |  | 1362d |  |  | Council; Policy Staff | 240h |  |
| 547 | 1.9.3.7.3 | **ICANN71** |  | 70d | 2021-04-01 | 2021-07-07 |  |  |  | 1303d |  |  |  | 1560h |  |
| 548 | 1.9.3.7.3.1 | Meeting Planning |  | 50d | 2021-04-01 | 2021-06-09 |  |  |  | 1303d | 0d | start no earlier than 2021-04-01 | Council Leads; Policy Staff | 800h |  |
| 549 | 1.9.3.7.3.2 | ICANN Meeting |  | 5d | 2021-06-10 | 2021-06-16 | 548 |  |  | 1303d | 0d | start no earlier than 2021-03-20 | Board; Contracted Parties; Council; Council Leads; EC Admin; EC Rep; Finance Staff; GDS Staff; IRT; Legal Staff; Policy Staff; SSC; Working Group | 520h |  |
| 550 | 1.9.3.7.3.3 | Respond to GAC Advice |  | 15d | 2021-06-17 | 2021-07-07 | 549 |  |  | 1303d |  |  | Council; Policy Staff | 240h |  |
| 551 | 1.9.3.7.4 | **ICANN72** |  | 102d | 2021-07-01 | 2021-11-18 |  |  |  | 1206d |  |  |  | 1960h |  |
| 552 | 1.9.3.7.4.1 | Meeting Planning |  | 75d | 2021-07-01 | 2021-10-13 |  |  |  | 1213d | 7d | start no earlier than 2021-07-01 | Council Leads; Policy Staff | 1200h |  |
| 553 | 1.9.3.7.4.2 | ICANN Meeting |  | 5d | 2021-10-23 | 2021-10-28 | 552 |  |  | 1206d | 0d | start no earlier than 2021-10-23 | Board; Contracted Parties; Council; Council Leads; EC Admin; EC Rep; Finance Staff; GDS Staff; IRT; Legal Staff; Policy Staff; SSC; Working Group | 520h |  |
| 554 | 1.9.3.7.4.3 | Respond to GAC Advice |  | 15d | 2021-10-29 | 2021-11-18 | 553 |  |  | 1206d |  |  | Council; Policy Staff | 240h |  |
| 555 | 1.9.3.7.5 | **ICANN73** |  | 95d | 2021-12-01 | 2022-04-12 |  |  |  | 1103d |  |  |  | 1960h |  |
| 556 | 1.9.3.7.5.1 | Meeting Planning |  | 75d | 2021-12-01 | 2022-03-15 |  |  |  | 1103d | 0d | start no earlier than 2021-12-01 | Council Leads; Policy Staff | 1200h |  |
| 557 | 1.9.3.7.5.2 | ICANN Meeting |  | 5d | 2022-03-16 | 2022-03-22 | 556 |  |  | 1103d | 0d | start no earlier than 2021-06-14 | Board; Contracted Parties; Council; Council Leads; EC Admin; EC Rep; Finance Staff; GDS Staff; IRT; Legal Staff; Policy Staff; SSC; Working Group | 520h |  |
| 558 | 1.9.3.7.5.3 | Respond to GAC Advice |  | 15d | 2022-03-23 | 2022-04-12 | 557 |  |  | 1103d |  |  | Council; Policy Staff | 240h |  |

| ID | WBS | Task | Duration | Start | Finish | Predecessors | Total slack | Free slack | Constraint | Resources | Work |
| --- | --- | --- | --- | --- | --- | --- | --- | --- | --- | --- | --- |
| 559 | 1.9.3.7.6 | **ICANN74** | 70d | 2022-04-01 | 2022-07-07 |  | 1041d |  |  |  | 1560h |
| 560 | 1.9.3.7.6.1 | Meeting Planning | 50d | 2022-04-01 | 2022-06-09 |  | 1041d | 0d | start no earlier than 2022-04-01 | Council Leads; Policy Staff | 800h |
| 561 | 1.9.3.7.6.2 | ICANN Meeting | 5d | 2022-06-10 | 2022-06-16 | 560 | 1041d | 0d | start no earlier than 2021-03-20 | Board; Contracted Parties; Council; Council Leads; EC Admin; EC Rep; Finance Staff; GDS Staff; IRT; Legal Staff; Policy Staff; SSC; Working Group | 520h |
| 562 | 1.9.3.7.6.3 | Respond to GAC Advice | 15d | 2022-06-17 | 2022-07-07 | 561 | 1041d |  |  | Council; Policy Staff | 240h |
| 563 | 1.9.3.7.7 | **ICANN75** | 95d | 2022-06-01 | 2022-10-11 |  | 973d |  |  |  | 1960h |
| 564 | 1.9.3.7.7.1 | Meeting Planning | 75d | 2022-06-01 | 2022-09-13 |  | 973d | 0d | start no earlier than 2022-06-01 | Council Leads; Policy Staff | 1200h |
| 565 | 1.9.3.7.7.2 | ICANN Meeting | 5d | 2022-09-14 | 2022-09-20 | 564 | 973d | 0d | start no earlier than 2021-10-23 | Board; Contracted Parties; Council; Council Leads; EC Admin; EC Rep; Finance Staff; GDS Staff; IRT; Legal Staff; Policy Staff; SSC; Working Group | 520h |
| 566 | 1.9.3.7.7.3 | Respond to GAC Advice | 15d | 2022-09-21 | 2022-10-11 | 565 | 973d |  |  | Council; Policy Staff | 240h |
| 567 | 1.9.3.7.8 | **ICANN76** | 95d | 2022-12-01 | 2023-04-11 |  | 842d |  |  |  | 1960h |
| 568 | 1.9.3.7.8.1 | Meeting Planning | 75d | 2022-12-01 | 2023-03-15 |  | 842d | 0d | start no earlier than 2022-12-01 | Council Leads; Policy Staff | 1200h |
| 569 | 1.9.3.7.8.2 | ICANN Meeting | 5d | 2023-03-16 | 2023-03-22 | 568 | 842d | 0d | start no earlier than 2021-06-14 | Board; Contracted Parties; Council; Council Leads; EC Admin; EC Rep; Finance Staff; GDS Staff; IRT; Legal Staff; Policy Staff; SSC; Working Group | 520h |
| 570 | 1.9.3.7.8.3 | Respond to GAC Advice | 15d | 2023-03-23 | 2023-04-11 | 569 | 842d |  |  | Council; Policy Staff | 240h |
| 571 | 1.9.3.7.9 | **ICANN77** | 70d | 2023-04-01 | 2023-07-05 |  | 780d |  |  |  | 1560h |
| 572 | 1.9.3.7.9.1 | Meeting Planning | 50d | 2023-04-01 | 2023-06-08 |  | 780d | 0d | start no earlier than 2023-04-01 | Council Leads; Policy Staff | 800h |
| 573 | 1.9.3.7.9.2 | ICANN Meeting | 5d | 2023-06-09 | 2023-06-15 | 572 | 780d | 0d | start no earlier than 2021-03-20 | Board; Contracted Parties; Council; Council Leads; EC Admin; EC Rep; Finance Staff; GDS Staff; IRT; Legal Staff; Policy Staff; SSC; Working Group | 520h |
| 574 | 1.9.3.7.9.3 | Respond to GAC Advice | 15d | 2023-06-16 | 2023-07-05 | 573 | 780d |  |  | Council; Policy Staff | 240h |
| 575 | 1.9.3.7.10 | **ICANN78** | 95d | 2023-07-01 | 2023-11-09 |  | 689d |  |  |  | 1960h |
| 576 | 1.9.3.7.10.1 | Meeting Planning | 75d | 2023-07-01 | 2023-10-12 |  | 689d | 0d | start no earlier than 2023-07-01 | Council Leads; Policy Staff | 1200h |
| 577 | 1.9.3.7.10.2 | ICANN Meeting | 5d | 2023-10-13 | 2023-10-19 | 576 | 689d | 0d | start no earlier than 2021-10-23 | Board; Contracted Parties; Council; Council Leads; EC Admin; EC Rep; Finance Staff; GDS Staff; IRT; Legal Staff; Policy Staff; SSC; Working Group | 520h |
| 578 | 1.9.3.7.10.3 | Respond to GAC Advice | 15d | 2023-10-20 | 2023-11-09 | 577 | 689d |  |  | Council; Policy Staff | 240h |
| 579 | 1.9.3.7.11 | **ICANN79** | 95d | 2023-12-01 | 2024-04-11 |  | 579d |  |  |  | 1960h |
| 580 | 1.9.3.7.11.1 | Meeting Planning | 75d | 2023-12-01 | 2024-03-14 |  | 579d | 0d | start no earlier than 2023-12-01 | Council Leads; Policy Staff | 1200h |
| 581 | 1.9.3.7.11.2 | ICANN Meeting | 5d | 2024-03-15 | 2024-03-21 | 580 | 579d | 0d | start no earlier than 2021-06-14 | Board; Contracted Parties; Council; Council Leads; EC Admin; EC Rep; Finance Staff; GDS Staff; IRT; Legal Staff; Policy Staff; SSC; Working Group | 520h |
| 582 | 1.9.3.7.11.3 | Respond to GAC Advice | 15d | 2024-03-22 | 2024-04-11 | 581 | 579d |  |  | Council; Policy Staff | 240h |

| ID | WBS | Task | Duration | Start | Finish | Predecessors | Total slack | Free slack | Constraint | Resources | Work |
| --- | --- | --- | --- | --- | --- | --- | --- | --- | --- | --- | --- |
| 583 | 1.9.3.7.12 | **ICANN80** | 70d | 2024-04-01 | 2024-07-05 |  | 518d |  |  |  | 1560h |
| 584 | 1.9.3.7.12.1 | Meeting Planning | 50d | 2024-04-01 | 2024-06-07 |  | 518d | 0d | start no earlier than 2024-04-01 | Council Leads; Policy Staff | 800h |
| 585 | 1.9.3.7.12.2 | ICANN Meeting | 5d | 2024-06-10 | 2024-06-14 | 584 | 518d | 0d | start no earlier than 2021-03-20 | Board; Contracted Parties; Council; Council Leads; EC Admin; EC Rep; Finance Staff; GDS Staff; IRT; Legal Staff; Policy Staff; SSC; Working Group | 520h |
| 586 | 1.9.3.7.12.3 | Respond to GAC Advice | 15d | 2024-06-17 | 2024-07-05 | 585 | 518d |  |  | Council; Policy Staff | 240h |
| 587 | 1.9.3.7.13 | **ICANN81** | 95d | 2024-07-01 | 2024-11-08 |  | 428d |  |  |  | 1960h |
| 588 | 1.9.3.7.13.1 | Meeting Planning | 75d | 2024-07-01 | 2024-10-11 |  | 428d | 0d | start no earlier than 2024-07-01 | Council Leads; Policy Staff | 1200h |
| 589 | 1.9.3.7.13.2 | ICANN Meeting | 5d | 2024-10-14 | 2024-10-18 | 588 | 428d | 0d | start no earlier than 2021-10-23 | Board; Contracted Parties; Council; Council Leads; EC Admin; EC Rep; Finance Staff; GDS Staff; IRT; Legal Staff; Policy Staff; SSC; Working Group | 520h |
| 590 | 1.9.3.7.13.3 | Respond to GAC Advice | 15d | 2024-10-21 | 2024-11-08 | 589 | 428d |  |  | Council; Policy Staff | 240h |
| 591 | 1.9.3.7.14 | **ICANN82** | 95d | 2024-12-01 | 2025-04-10 |  | 318d |  |  |  | 1960h |
| 592 | 1.9.3.7.14.1 | Meeting Planning | 75d | 2024-12-01 | 2025-03-13 |  | 318d | 0d | start no earlier than 2024-12-01 | Council Leads; Policy Staff | 1200h |
| 593 | 1.9.3.7.14.2 | ICANN Meeting | 5d | 2025-03-14 | 2025-03-20 | 592 | 318d | 0d | start no earlier than 2021-06-14 | Board; Contracted Parties; Council; Council Leads; EC Admin; EC Rep; Finance Staff; GDS Staff; IRT; Legal Staff; Policy Staff; SSC; Working Group | 520h |
| 594 | 1.9.3.7.14.3 | Respond to GAC Advice | 15d | 2025-03-21 | 2025-04-10 | 593 | 318d |  |  | Council; Policy Staff | 240h |
| 595 | 1.9.3.7.15 | **ICANN83** | 70d | 2025-04-01 | 2025-07-07 |  | 256d |  |  |  | 1560h |
| 596 | 1.9.3.7.15.1 | Meeting Planning | 50d | 2025-04-01 | 2025-06-09 |  | 256d | 0d | start no earlier than 2025-04-01 | Council Leads; Policy Staff | 800h |
| 597 | 1.9.3.7.15.2 | ICANN Meeting | 5d | 2025-06-10 | 2025-06-16 | 596 | 256d | 0d | start no earlier than 2021-03-20 | Board; Contracted Parties; Council; Council Leads; EC Admin; EC Rep; Finance Staff; GDS Staff; IRT; Legal Staff; Policy Staff; SSC; Working Group | 520h |
| 598 | 1.9.3.7.15.3 | Respond to GAC Advice | 15d | 2025-06-17 | 2025-07-07 | 597 | 256d |  |  | Council; Policy Staff | 240h |
| 599 | 1.9.3.7.16 | **ICANN84** | 95d | 2025-07-01 | 2025-11-10 |  | 166d |  |  |  | 1960h |
| 600 | 1.9.3.7.16.1 | Meeting Planning | 75d | 2025-07-01 | 2025-10-13 |  | 166d | 0d | start no earlier than 2025-07-01 | Council Leads; Policy Staff | 1200h |
| 601 | 1.9.3.7.16.2 | ICANN Meeting | 5d | 2025-10-14 | 2025-10-20 | 600 | 166d | 0d | start no earlier than 2021-10-23 | Board; Contracted Parties; Council; Council Leads; EC Admin; EC Rep; Finance Staff; GDS Staff; IRT; Legal Staff; Policy Staff; SSC; Working Group | 520h |
| 602 | 1.9.3.7.16.3 | Respond to GAC Advice | 15d | 2025-10-21 | 2025-11-10 | 601 | 166d |  |  | Council; Policy Staff | 240h |
| 603 | 1.9.3.7.17 | **ICANN85** | 95d | 2025-12-01 | 2026-04-10 |  | 57d |  |  |  | 1960h |
| 604 | 1.9.3.7.17.1 | Meeting Planning | 75d | 2025-12-01 | 2026-03-13 |  | 57d | 0d | start no earlier than 2025-12-01 | Council Leads; Policy Staff | 1200h |
| 605 | 1.9.3.7.17.2 | ICANN Meeting | 5d | 2026-03-16 | 2026-03-20 | 604 | 57d | 0d | start no earlier than 2021-06-14 | Board; Contracted Parties; Council; Council Leads; EC Admin; EC Rep; Finance Staff; GDS Staff; IRT; Legal Staff; Policy Staff; SSC; Working Group | 520h |
| 606 | 1.9.3.7.17.3 | Respond to GAC Advice | 15d | 2026-03-23 | 2026-04-10 | 605 | 57d |  |  | Council; Policy Staff | 240h |

| ID | WBS | Task | Duration | Start | Finish | Predecessors | Total slack | Constraint | Resources | Work |
| --- | --- | --- | --- | --- | --- | --- | --- | --- | --- | --- |
| 607 | 1.9.3.7.18 | **ICANN86** | 65d | 2026-04-01 | 2026-06-30 |  | 0d |  |  | 1480h |
| 608 | 1.9.3.7.18.1 | Meeting Planning | 50d | 2026-04-01 | 2026-06-09 |  | 0d | start no earlier than 2026-04-01 | Council Leads; Policy Staff | 800h |
| 609 | 1.9.3.7.18.2 | ICANN Meeting | 5d | 2026-06-10 | 2026-06-16 | 608 | 0d | start no earlier than 2021-03-20 | Board; Contracted Parties; Council; Council Leads; EC Admin; EC Rep; Finance Staff; GDS Staff; IRT; Legal Staff; Policy Staff; SSC; Working Group | 520h |
| 610 | 1.9.3.7.18.3 | Respond to GAC Advice | 10d | 2026-06-17 | 2026-06-30 | 609 | 0d |  | Council; Policy Staff | 160h |
